# 3GPP_Release-2000

Schedule from MS Project, 2000-01-03 to 2007-03-30, A marks actual dates.

## Calendars

- Standard: Mon-Fri 08:00-12:00, 13:00-17:00; Sat-Sun off.

## Resources

| Resource |
| --- |
| NP |
| N1 |
| N2 |
| N3 |
| N4 |
| N5 |
| TP |
| T1 |
| T2 |
| T3 |
| RP |
| R1 |
| R2 |
| R3 |
| R4 |
| SP |
| S1 |
| S2 |
| S3 |
| S4 |
| S5 |
| PCG |
| GP |
| No |
| CN4 |
| ? |
| WG G2 |
| G2 |
| G1 |
| G4 |
| G3 |
| All |
| Generic |
| MLST |
| G5 |
| S3; G2 |
| WG T2 |
| GP;G1 |
| G4;G5 |
| OMA |
| GP-G2 |
| Yes |
| GP; |
| N4; |
| GP; N1 |
| CT5 |
| C5 |
| C1 |
| C4 |
| C3 |
| C6 |
| G1; |

## Schedule

| ID | WBS | Task | Type | Duration | Start | Finish | Complete | Remaining | Baseline start | Baseline finish | Baseline duration | Total slack | Constraint | Resources | Work | Actual work | Text9 | Text6 | Text1 | Text3 | Text4 | Text5 | Text7 | Text8 | Text2 | Text12 |
| --- | --- | --- | --- | --- | --- | --- | --- | --- | --- | --- | --- | --- | --- | --- | --- | --- | --- | --- | --- | --- | --- | --- | --- | --- | --- | --- |
| 1 | 1 | VERSION 2005 November 4th |  | 1d | 2000-01-03 | 2000-01-03 |  |  | 2000-01-03 | 2000-01-03 | 1d | 1889d |  |  |  |  | 2044 |  |  |  |  |  |  |  |  |  |
| 2 | 2 | "CTRL + a" to display all the 3GPP fields |  | 1d | 2000-01-03 | 2000-01-03 |  |  | 2000-01-03 | 2000-01-03 | 1d | 1889d |  |  |  |  | 1462 |  |  |  |  |  |  |  |  |  |
| 3 | 3 | Content of Release 7, not frozen |  | 1d | 2000-01-03 | 2000-01-03 |  |  | 2000-01-03 | 2000-01-03 | 1d | 1889d |  |  |  |  | 2058 |  |  |  |  |  |  |  |  |  |
| 5 | 4 | Rel-7 Features listed below |  | 1d? | 2000-01-03 | 2000-01-03 |  |  | 2000-01-03 | 2000-01-03 | 1d? | 1889d |  |  |  |  |  | Rel-7 |  |  |  |  |  |  |  |  |
| 6 | 8.5 | **Multiple Input Multiple Output antennas (MIMO)** |  | 720d? | 2003-03-14 A | 2005-12-15 | 12% | 636.47d? | 2003-03-14 | 2005-12-15 | 720d? | 336d |  | R1 | 25136h | 4347.2h | 2468 | Rel-7 | MIMO | TR25.876,TR25.996 | Howard Huang, Lucent | hchuang@lucent.com | TSG | Cesar |  |  |
| 7 | 5.1 | MIMO - Physical layer |  | 590d? | 2003-09-12 A | 2005-12-15 | 43% | 335.2d? | 2003-09-12 | 2005-12-15 | 590d? | 336d | finish no earlier than 2005-12-15 | R1 | 4720h | 2038.4h |  | Rel-7 | MIMO-Phys | 25.211, 25.212, 25.213, 25.214, 25.215, 25.221, 25 | Howard Huang, Lucent | hchuang@lucent.com | TSG | MCC_RAN |  |  |
| 8 | 5.2 | MIMO - Layer 2,3 aspects |  | 589d? | 2003-09-12 | 2005-12-15 |  |  | 2003-09-12 | 2005-12-15 | 589d? | 337d | finish no earlier than 2005-12-15 | R2 | 4712h |  |  | Rel-7 | MIMO-L23 | TR 25.876 | Howard Huang, Lucent | hchuang@lucent.com | TSG | MCC_RAN |  |  |
| 9 | 5.3 | MIMO - Iub/Iur Protocol Aspects |  | 719d? | 2003-03-14 | 2005-12-15 |  |  | 2003-03-14 | 2005-12-15 | 719d? | 337d | finish no earlier than 2005-12-15 | R3 | 5752h |  |  | Rel-7 | MIMO-IurIub |  | Howard Huang, Lucent | hchuang@lucent.com | TSG | MCC_RAN |  |  |
| 10 | 5.4 | MIMO - RF Radio Transmission/Reception, System Performance Requirements and Conformance Testing |  | 524d? | 2003-12-12 A | 2005-12-15 | 5% | 497.8d? | 2003-12-12 | 2005-12-15 | 524d? | 337d | finish no earlier than 2005-12-15 | R4 | 4192h | 209.6h |  | Rel-7 | MIMO-RF |  | Man Hung Ng, Lucent | ngm@lucent.com | TSG | MCC_RAN |  |  |
| 11 | 6 | **PS domain and IMS impacts for supporting IMS Emergency calls** |  | 1520d? | 2000-08-14 A | 2006-06-09 | 38% | 943.61d? | 2000-08-14 | 2006-06-09 | 1520d? | 210d |  | S2 | 60544h | 19151.3h |  | Rel-7 | EMC1 |  | Rainer Liebhart |  | TSG | Maurice |  |  |
| 12 | 10.1.1 | Service Requirements for IP-based emergency calls |  | 985d | 2000-09-18 A | 2004-06-25 A | 100% |  | 2000-09-18 | 2004-06-25 | 985d |  | finish no earlier than 2004-06-25 | S1 | 7880h | 7880h | 1314 | Rel-7 | EMC1 | 22.976 |  |  |  |  | CCaR |  |
| 13 | 6.2 | Study on Stage 2 for IMS-level solution |  | 668d? | 2003-02-26 A | 2005-09-16 | 90% | 66.8d? | 2003-02-26 | 2005-09-16 | 668d? | 400d | finish no earlier than 2005-09-16 | S2 | 5344h | 4809.6h |  | Rel-7 | EMC1 | 23.228, 23.060, 23.002 | Rainer Liebhart, Siemenws |  | TSG |  |  |  |
| 14 | 6.3 | Study on Stage 2 for GPRS-level solution |  | 301d? | 2004-10-14 A | 2005-12-08 | 80% | 60.2d? | 2004-10-14 | 2005-12-08 | 301d? | 341d | finish no earlier than 2005-12-08 | S2 | 2408h | 1926.4h |  | Rel-7 | EMC1 |  |  |  |  |  |  |  |
| 15 | 6.4 | Stage 2 Specification Phase - IMS-level |  | 200d? | 2005-09-05 | 2006-06-09 |  |  | 2005-09-05 | 2006-06-09 | 200d? | 210d | finish no earlier than 2006-06-09 | S2 | 1600h |  |  | Rel-7 | EMC1 |  |  |  |  |  |  |  |
| 16 | 6.5 | Stage 2 Specification Phase - GPRS-level |  | 200d? | 2005-09-05 | 2006-06-09 |  |  | 2005-09-05 | 2006-06-09 | 200d? | 210d | finish no earlier than 2006-06-09 | S2 | 1600h |  |  | Rel-7 | EMC1 |  |  |  |  |  |  |  |
| 17 | 10.1 | **Emergency Call Enhancements for IP& PS Based Calls – stage 3** |  | 1280.1d | 2000-08-14 A | 2005-07-11 |  | 1280.1d | 2000-08-14 | 2005-07-11 | 1280.1d | 449.9d |  | C1 | 29752h |  | 1653 | Rel-7 | EMC1 |  | Mr Atle Monrad, Ericsson | Atle.Monrad@eto.ericsson.se |  |  | CCaR |  |
| 18 | 10.1.2 | IMS aspects to support IMS Emergency sessions |  | 1209d | 2000-10-17 A | 2005-07-08 |  | 1209d | 2000-10-17 | 2005-07-08 | 1209d | 450.82d | finish no earlier than 2005-06-03 | C1 | 9672h |  | 1315 | Rel-7 | EMC1 | 24.229 | Mr Atle Monrad, Ericsson | Atle.Monrad@eto.ericsson.se |  |  | CCaR |  |
| 19 | 10.1.5 | PS domain aspects to support IMS Emergency sessions |  | 1255d | 2000-08-14 A | 2005-07-11 |  | 1255d | 2000-08-14 | 2005-07-11 | 1255d | 449.9d | finish no earlier than 2005-06-03 | C1 | 10040h |  | 1646 | Rel-7 | EMC1 | 24.008 | Mr Atle Monrad, Ericsson | Atle.Monrad@eto.ericsson.se |  |  | CCaR |  |
| 20 | 7 | **Check - PS domain and IMS support for IMS Emergency sessions** |  | 185d? | 2005-10-10 A | 2006-06-23 |  | 185d? | 2005-10-10 | 2006-06-23 | 185d? | 200d |  | S2 | 1940.97h |  |  | Rel-7 | IMS-EMER | 23.867, TS 23.abc, 23.060, 23.002, 23.271 | Curt Wong (Nokia) | curt.c.wong@nokia.com |  | Maurice |  |  |
| 21 | 7.1 | IMS aspects to support IMS Emergency sessions |  | 121.31d? | 2005-10-10 A | 2006-06-23 |  | 121.31d? | 2005-10-10 | 2006-06-23 | 121.31d? | 200d | finish no earlier than 2006-06-23 | S2 | 970.48h |  |  | Rel-7 | IMS-EMER | 23.867, TS 23.abc, 23.060, 23.002, 23.271 | Curt Wong (Nokia) | curt.c.wong@nokia.com | TSG | Maurice |  |  |
| 22 | 7.2 | PS domain aspects to support IMS Emergency sessions |  | 121.31d? | 2005-10-10 A | 2006-06-23 |  | 121.31d? | 2005-10-10 | 2006-06-23 | 121.31d? | 200d | finish no earlier than 2006-06-23 | S2 | 970.48h |  |  | Rel-7 | IMS-EMER | 23.867, TS 23.abc, 23.060, 23.002, 23.271 | Curt Wong (Nokia) | curt.c.wong@nokia.com | TSG | Maurice |  |  |
| 23 | 8 | **Access Class Barring and Overload Protection** |  | 440d? | 2004-03-15 A | 2005-11-18 | 38% | 270.77d? | 2004-03-15 | 2005-11-18 | 440d? | 355d |  | S2 | 9240h | 3553.84h |  | Rel-7 | ACBOP | 23.898 | Chris Pudney, Vodafone |  | TSG | Maurice |  |  |
| 24 | 8.1 | TR on Stage 2 |  | 274d? | 2004-03-15 A | 2005-03-31 A | 100% |  | 2004-03-15 | 2005-03-31 | 274d? |  | finish no earlier than 2005-03-31 | S2 | 2192h | 2192h |  | Rel-7 | ACBOP |  |  |  | TSG |  |  |  |
| 25 | 8.2 | Extra ACBOP information in GERAN |  | 440d? | 2004-03-15 | 2005-11-18 |  |  | 2004-03-15 | 2005-11-18 | 440d? | 355d | finish no earlier than 2005-11-18 | GP | 3520h |  |  | Rel-7 | ACBOP | 44.018 |  |  | TSG | Gert |  |  |
| 26 | 8.3 | Stage 3 CN aspects of ACBOP |  | 1d? | 2004-12-08 A | 2004-12-08 A | 100% |  | 2004-12-08 | 2004-12-08 | 1d? |  | finish no earlier than 2004-12-08 | C1 | 8h | 8h |  | Rel-7 | ACBOP |  |  |  |  |  |  |  |
| 27 | 8.4 | Deleted - Potential impact on Iu interface Overload functionality | milestone | 0d? | 2004-03-15 A | 2004-03-15 A | 100% |  | 2004-03-15 | 2004-03-15 | 0d? |  | finish no earlier than 2004-03-15 | RP |  |  |  | Rel-7 | ACBOP | 25.413 |  |  |  |  |  | RP-25 |
| 28 | 8.5 | Deleted - Extra ACBOP information in RAN | milestone | 0d? | 2004-03-15 A | 2004-03-15 A | 100% |  | 2004-03-15 | 2004-03-15 | 0d? |  | finish no earlier than 2004-03-15 | RP |  |  |  | Rel-7 | ACBOP | 25.331 |  |  |  |  |  | RP-25 |

Notes:
- 20: Approved at SP#29
- 21: Approved at SP#29
- 22: Approved at SP#29
- 26: NEW - inserted on 2/9/2004

| ID | WBS | Task | Duration | Start | Finish | Complete | Remaining | Baseline start | Baseline finish | Baseline duration | Total slack | Constraint | Resources | Work | Actual work | Text1 | Text3 | Text6 | Text7 | Text8 | Text5 |
| --- | --- | --- | --- | --- | --- | --- | --- | --- | --- | --- | --- | --- | --- | --- | --- | --- | --- | --- | --- | --- | --- |
| 29 | 9 | **USSD message delivery and transfer to USIM** | 376d? | 2004-03-05 A | 2005-08-12 | 91% | 33.1d? | 2004-03-05 | 2005-11-16 | 443.7d? | 425d |  | S1 | 5698.4h | 5196.72h | USSD-USIM | 22.090 | Rel-7 | TSG | Michael |  |
| 30 | 9.1 | Stage 1 | 152d? | 2004-03-18 A | 2004-10-15 | 80% | 30.4d? | 2004-03-18 | 2004-10-15 | 152d? | 640d | start no earlier than 2004-03-18 | S1 | 1216h | 972.8h | USSD-USIM | 22.090 | Rel-7 | TSG | Michael |  |
| 31 | 9.2 | Alignment with requirements regarding USSD usage | 193.3d? | 2004-03-05 A | 2005-08-12 A | 100% |  | 2004-03-05 | 2005-11-16 | 261d? |  | finish no earlier than 2005-08-12 | C6 | 1546.4h | 1546.4h | USSD-USIM |  | Rel-7 | TSG |  | cdubois@axalto.com |
| 32 | 10 | **Location Services enhancements Rel-7** | 565d? | 2004-06-28 A | 2006-08-25 | 56% | 248.43d? | 2004-06-28 | 2006-08-25 | 565d? | 155d |  | S2 | 24700.4h | 12072.2h | LCS3 | 23.271 | Rel-7 |  | Maurice |  |
| 33 | 10.1 | Global Stage 2 for LCS3 | 321d? | 2004-12-31 A | 2006-03-24 | 55% | 144.45d? | 2004-12-31 | 2006-03-24 | 321d? | 265d | finish no earlier than 2006-03-24 | S2 | 2568h | 1412.4h | LCS3 | 23.271 | Rel-7 | TSG | Maurice | brodilitz@sirf.com |
| 34 | 10.2 | **LCS for 3GPP Interworking WLAN** | 565d? | 2004-06-28 A | 2006-08-25 | 74% | 145.63d? | 2004-06-28 | 2006-08-25 | 565d? | 155d |  | S1 | 7148.37h | 2049.27h | LCS3-IWLAN | 22.935 | Rel-7 | TSG | Michael |  |
| 35 | 10.2.1 | FS on 3GPP system to WLAN Interworking with LCS | 316.7d? | 2004-06-28 A | 2005-09-29 | 77% | 72.84d? | 2004-06-28 | 2005-09-29 | 316.7d? | 391d | finish no earlier than 2005-09-29 | S1 | 2533.6h | 1950.87h | LCS3-IWLAN | 22.935 | Rel-7 |  |  |  |
| 36 | 10.2.2 | Stage 2 work on an LCS architecture for I-WLAN. | 11.85d? | 2005-10-10 A | 2006-08-25 |  | 11.85d? | 2005-10-10 | 2006-08-25 | 11.85d? | 155d | finish no earlier than 2006-08-25 | S2 | 94.77h |  | LCS3-IWLAN | 23.8yz | Rel-7 |  | Maurice | dhshim@lge.com ; phede@lge.com |
| 37 | 10.3 | **UE positioning Rel-7** | 456d? | 2004-09-15 A | 2006-06-15 | 74% | 117.14d? | 2004-09-15 | 2006-06-15 | 456d? | 207d |  | RP | 7824h | 5814.04h | LCS3-UEpos |  | Rel-7 | TSG | Cesar |  |
| 38 | 10.3.1 | Inclusion of Uplink TDOA UE positioning method in the UTRAN specifications | 456d? | 2004-09-15 A | 2006-06-15 | 80% | 91.2d? | 2004-09-15 | 2006-06-15 | 456d? | 207d | finish no earlier than 2006-06-15 | R2 | 3648h | 2918.4h | LCS3-UEPos-UTDOA | TS25.305, TS25.453 | Rel-7 | TSG | MCC_RAN | rlgross@trueposition.com |
| 39 | 10.3.2 | LCS Enhancements Related to Location-Based Services | 66d? | 2005-03-15 A | 2005-06-15 | 35% | 42.9d? | 2005-03-15 | 2005-06-15 | 66d? | 468d | finish no earlier than 2005-06-15 | R2 | 528h | 184.8h | LCS3-UEPos-Velocity | 25.305, 25.331, 25.410, 25.413, 25.453 | Rel-7 | TSG | MCC_RAN | BRodilitz@SiRF.com |
| 40 | 10.4 | LCS Enhancements Related to Location-Based Services | 330d? | 2005-01-03 A | 2006-04-07 | 10% | 297d? | 2005-01-03 | 2006-04-07 | 330d? | 255d |  | GP | 2640h | 264h | LCS3-LBS | 43.059, 44.031, 48.008, 49.031 | Rel-7 | TSG | Paolo | kjudge@sirf.com |
| 41 | 11 | **Advanced Global Navigation Satellite System (A-GNSS) concept** | 470d? | 2004-06-28 A | 2006-04-14 | 17% | 388.12d? | 2004-06-28 | 2006-04-14 | 470d? | 250d |  | S1 | 9649.6h | 1176.4h | LCS3-AGNSS |  | Rel-7 | TSG | Michael | Michel.monnerat@space.alcatel.fr |
| 42 | 11.1 | Support for GNSS in GERAN | 451.2d? | 2004-06-28 | 2006-04-14 |  |  | 2004-06-28 | 2006-04-14 | 451.2d? | 250d | finish no earlier than 2006-04-14 | GP | 3609.6h |  | AGNSS-GP |  | Rel-7 | TSG | Paolo | richard.couty@space.alcatel.fr |
| 43 | 11.2 | Towards A-GNSS Concept | 285d? | 2004-08-27 A | 2005-09-29 | 45% | 156.75d? | 2004-08-27 | 2005-09-29 | 285d? | 391d | finish no earlier than 2005-09-29 | S1 | 2280h | 1026h | GNSS |  | Rel-7 | TSG | Paolo | richard.couty@space.alcatel.fr |
| 44 | 12 | **Combinational Services** | 233d? | 2005-01-17 A | 2005-12-07 | 58% | 98.94d? | 2005-01-17 | 2005-12-07 | 233d? | 342d |  | S1 | 6312h | 3631.67h | CSICS |  | Rel-7 | TSG | Michael | Robert.Frank@teliasonera.com |
| 45 | 12.1 | Stage 1 for CSICS | 104d? | 2005-01-17 A | 2005-06-09 | 90% | 10.4d? | 2005-01-17 | 2005-06-09 | 104d? | 471d | start no earlier than 2005-01-17 | S1 | 832h | 748.8h | CSICS | 22.279 | Rel-7 | TSG |  |  |
| 46 | 12.2 | Stage 2 for CSICS | 130d? | 2005-01-17 A | 2005-07-15 | 95% | 6.5d? | 2005-01-17 | 2005-07-15 | 130d? | 445d | start no earlier than 2005-01-17 | S2 | 1040h | 988h | CSICS | 23.279 | Rel-7 |  |  |  |
| 47 | 12.3 | Stage 3 for CSICS CN aspects | 130d? | 2005-05-02 A | 2005-10-28 | 20% | 104d? | 2005-05-02 | 2005-10-28 | 130d? | 370d | start no earlier than 2005-05-01 | C1 | 1040h | 208h | CSICS | 24.229, 24.008 | Rel-7 | TSG | Andrijana |  |
| 48 | 12.4 | Stage 3 for codec aspects | 192d? | 2005-03-15 A | 2005-12-07 | 40% | 115.2d? | 2005-03-15 | 2005-12-07 | 192d? | 342d | finish no earlier than 2005-12-07 | S4 | 1536h | 614.4h | CSICS-Codec | TS 26.141, 26.235, 26.236 | Rel-7 | TSG | Paolo | Per.Frojdh@ericsson.com |
| 49 | 13 | **All-IP Network (AIPN)** | 448d? | 2004-06-28 A | 2006-03-15 | 82% | 78.89d? | 2004-06-28 | 2006-03-15 | 448d? | 272d |  | S1 | 8672h | 7144.85h | AIPN | 22.978 | Rel-7 | TSG | Michael | c.masyu@nttdocomo.co.jp |
| 50 | 13.1 | All-IP Network Feasibility Study | 188d? | 2004-06-28 A | 2005-03-16 A | 100% |  | 2004-06-28 | 2005-03-16 | 188d? |  | start no earlier than 2004-06-28 | S1 | 1504h | 1504h | AIPFS | 22.978 | Rel-7 | TSG | Michael | c.masyu@nttdocomo.co.jp |
| 51 | 13.2 | Stage1 | 448d? | 2004-06-28 A | 2006-03-15 | 75% | 112d? | 2004-06-28 | 2006-03-15 | 448d? | 272d | finish no earlier than 2006-03-15 | S1 | 3584h | 2688h | AIPN | 22.258 | Rel-7 | TSG | Michael | c.masyu@nttdocomo.co.jp |
| 52 | 14 | Enhancement of E2E QoS | 336.4d? | 2004-06-28 A | 2005-12-01 A | 100% |  | 2004-06-28 | 2005-12-01 | 336.4d? |  | finish no earlier than 2005-12-01 | S2 | 2691.2h | 2691.2h | QoS7 | 23.802 | Rel-7 | TSG | Maurice |  |

Notes:
- 31: Text4: Christophe Dubois (Axalto)
- 33: Approved SA#27. Appropriate place forEmergency work to be found / Text4: Ben Rodilitz, SiRF
- 34: Text4: Mike Loushine, (Telcordia)
- 35: DAB - Should be SA1
- 36: Approved in SP#29 / Text4: Donghee Shim (LG Electronics Inc.); Patrice HÉDÉ (LG Electronics Mobilecomm France)
- 38: Text4: Robert Gross, TruePosition
- 39: Text4: Ben Rodilitz
- 40: Linked SP-040682 / Text4: Kevin Judge, SiRF Technologies
- 41: Text4: Michel MONNERAT
- 42: Not started / Text4: Richard Couty, ALCATEL SA
- 43: Text4: Richard Couty, ALCATEL SA
- 44: Text4: Robert Frank, TeliaSonera
- 47: Text4: Peter Dawes (Vodafone)
- 48: Started / Text4: Per Fröjdh, Ericsson
- 49: Text4: Chris Sachno (NTT DoCoMo)
- 50: Text4: Chris Sachno (NTT DoCoMo)
- 51: Text4: Chris Sachno (NTT DoCoMo)
- 52: DAB - pushed back to June

| ID | WBS | Task | Type | Duration | Start | Finish | Complete | Remaining | Baseline start | Baseline finish | Baseline duration | Total slack | Constraint | Resources | Work | Actual work | Text1 | Text6 | Text7 | Text8 | Text4 | Text5 |
| --- | --- | --- | --- | --- | --- | --- | --- | --- | --- | --- | --- | --- | --- | --- | --- | --- | --- | --- | --- | --- | --- | --- |
| 53 | 15 | **System enhancements for fixed broadband access to IMS** |  | 353d? | 2004-08-03 A | 2005-12-08 | 52% | 170.43d? | 2004-08-03 | 2005-12-08 | 353d? | 341d |  | S2 | 7401.6h | 3828.06h | FBI | Rel-7 | TSG | Maurice |  |  |
| 54 | 15.1 | Stage 2 |  | 301d? | 2004-10-14 A | 2005-12-08 | 47% | 159.53d? | 2004-10-14 | 2005-12-08 | 301d? | 341d | finish no earlier than 2005-12-08 | S2 | 2408h | 1131.76h | FBI | Rel-7 | TSG | Maurice |  |  |
| 55 | 15.2 | Protocol impact from providing IMS services via fixed broadband |  | 347d? | 2004-08-03 A | 2005-11-30 | 70% | 104.1d? | 2004-08-03 | 2005-11-30 | 347d? | 347d | finish no earlier than 2005-03-03 | C1 | 2776h | 1943.2h | FBI | Rel-7 | TSG | Andrijana | Siemens |  |
| 56 | 15.3 | Security Enhancements for Fixed Broadband Access to IMS |  | 118d? | 2005-06-28 A | 2005-12-08 | 10% | 106.2d? | 2005-06-28 | 2005-12-08 | 118d? | 341d | start no earlier than 2005-06-28 | S3 | 944h | 94.4h | ISE | Rel-7 |  | Mike | Bengt Sahlin, Ericsson | Bengt.Sahlin@ericsson.com |
| 57 | 16 | Access Security Enhancements |  | 195d? | 2005-01-03 A | 2005-09-30 | 30% | 136.5d? | 2005-01-03 | 2005-09-30 | 195d? | 390d | finish no earlier than 2005-09-30 | S3 | 1560h | 468h | ACCSEC2 | Rel-7 | TSG | Michael | Bengt Sahlin, Ericsson | Bengt.Sahlin@ericsson.com |
| 58 | 17 | Mp (MRFC - MRFP) interface |  | 644d | 2002-12-13 | 2005-06-01 |  |  | 2002-12-13 | 2005-06-01 | 644d | 477d | finish no earlier than 2005-06-01 | C4 | 5152h |  | IMSLocal | Rel-7 |  |  |  |  |
| 59 | 18 | IMS Stage 3 IETF Protocol alignment |  | 261d? | 2004-12-10 A | 2005-12-09 | 20% | 208.8d? | 2004-12-10 | 2005-12-09 | 261d? | 340d | finish no earlier than 2005-12-09 | C1 | 2088h | 417.6h | IMSProtoc | Rel-7 |  |  |  |  |
| 60 | 19 | **Rel-7 Improvements of the Radio Interface** |  | 456d? | 2004-09-15 A | 2006-06-15 | 56% | 199.46d? | 2004-09-15 | 2006-06-15 | 456d? | 207d |  | RP | 16680h | 9383.91h | RInImp | Rel-7 |  | Cesar |  |  |
| 61 | 19.1 | UMTS 2.6 GHz |  | 195d? | 2004-09-15 A | 2005-06-14 A | 100% |  | 2004-09-15 | 2005-06-14 | 195d? |  | finish no earlier than 2005-06-14 | R4 | 1560h | 1560h | RInImp-UMTS2600 | Rel-7 | TSG | Cesar | Jussi Numminen, Nokia | jussi.numminen@nokia.com |
| 62 | 19.2 | UMTS 2.6 GHz TDD |  | 261d? | 2004-12-15 A | 2005-12-15 | 85% | 39.15d? | 2004-12-15 | 2005-12-15 | 261d? | 337d | finish no earlier than 2005-12-15 | R4 | 2088h | 1774.8h | RInImp-UMTS2600TDD | Rel-7 | TSG | MCC_RAN | Shin Horng Wong (IPWireless) | shwong@IPWIRELESS.COM |
| 63 | 19.3 | UMTS 900 MHz |  | 261d? | 2004-12-15 A | 2005-12-15 | 75% | 65.25d? | 2004-12-15 | 2005-12-15 | 261d? | 337d | finish no earlier than 2005-12-15 | R4 | 2088h | 1566h | RInImp-UMTS900 | Rel-7 | TSG | MCC_RAN | Yannick Li (Nortel) | yli@nortelnetworks.com |
| 64 | 19.4 | UMTS 1700 MHz |  | 197d? | 2005-03-15 A | 2005-12-15 | 80% | 39.4d? | 2005-03-15 | 2005-12-15 | 197d? | 337d | finish no earlier than 2005-12-15 | R4 | 1576h | 1260.8h | RInImp-UMTS1700 | Rel-7 | TSG | MCC_RAN | Takehiro Nakamura | NTT DoCoMo |
| 65 | 19.5 | Pending decision of the PCG!! UMTS 2.6 GHz FDD DL External |  | 195d? | 2005-09-15 | 2006-06-15 |  |  | 2005-09-15 | 2006-06-15 | 195d? | 207d | finish no earlier than 2006-06-15 | R4 | 1560h |  | RInImp-UMTS2600Ext | Rel-7 | TSG | MCC_RAN | Han van Bussel | han.van.bussel@t-mobile.de |
| 66 | 19.6 | UE Antenna Performance Evaluation Method and Requirements |  | 325d? | 2004-12-15 A | 2006-03-15 | 45% | 178.75d? | 2004-12-15 | 2006-03-15 | 325d? | 273d | finish no earlier than 2006-03-15 | R4 | 2600h | 1170h | RInImp-UEAnt | Rel-7 | TSG | MCC_RAN | Christian Bergljung (TeliaSonera) | Christian.Bergljung@TeliaSonera.com |
| 67 | 19.7 | Improved Performance Requirements for HSDPA UE based on Rx Diversity (type 1) & LMMSE equalizer (type 2) | milestone | 0d? | 2005-03-15 A | 2005-03-15 | 25% | 0d? | 2005-03-15 | 2005-03-15 | 0d? | 534d | finish no earlier than 2005-03-15 | R4 |  |  | RInImp-HSPerf-Type3 | Rel-7 | TSG | MCC_RAN | Marc Grant | marc.grant@cingular.com |
| 68 | 19.8 | Improved Performance Requirements for non-HSDPA channels based on Enhanced Receiver, Type 1 (Rx Diversity) |  | 195d? | 2005-09-15 | 2006-06-15 |  |  | 2005-09-15 | 2006-06-15 | 195d? | 207d | finish no earlier than 2006-06-15 | R4 | 1560h |  | RInImp-DCHPerf-RxDiv | Rel-7 | TSG | MCC_RAN | Marc Grant | marc.grant@cingular.com |
| 69 | 20 | **7.68Mcps TDD option** |  | 456d? | 2004-09-15 A | 2006-06-15 | 38% | 283.73d? | 2004-09-15 | 2006-06-15 | 456d? | 207d |  | RP | 17728h | 6697.35h | VHCRTDD | Rel-7 | TSG | Cesar | Martin Beale, IPWireless | mbeale@ipwireless.com |
| 70 | 20.1 | VHCRTDD: Stage 2 |  | 326d? | 2004-09-15 A | 2005-12-15 | 15% | 277.1d? | 2004-09-15 | 2005-12-15 | 326d? | 337d | finish no earlier than 2005-12-15 | R1 | 2608h | 391.2h | VHCRTDD-Stage2 | Rel-7 | TSG | MCC_RAN | Martin Beale, IPWireless | mbeale@ipwireless.com |
| 71 | 20.2 | VHCRTDD: Physical Layer |  | 326d? | 2004-09-15 A | 2005-12-15 | 40% | 195.6d? | 2004-09-15 | 2005-12-15 | 326d? | 337d | finish no earlier than 2005-12-15 | R1 | 2608h | 1043.2h | VHCRTDD-Phys | Rel-7 | TSG | MCC_RAN | Martin Beale, IPWireless | mbeale@ipwireless.com |
| 72 | 20.3 | VHCRTDD: Layer 2 and layer 3 protocol aspects |  | 326d? | 2004-09-15 A | 2005-12-15 | 50% | 163d? | 2004-09-15 | 2005-12-15 | 326d? | 337d | finish no earlier than 2005-12-15 | R2 | 2608h | 1304h | VHCRTDD-L23 | Rel-7 | TSG | MCC_RAN | Derek Richards, IPWireless | drichards@ipwireless.com |
| 73 | 20.4 | VHCRTDD: UTRAN Iub/Iur Protocol Aspects |  | 326d? | 2004-09-15 A | 2005-12-15 | 50% | 163d? | 2004-09-15 | 2005-12-15 | 326d? | 337d | finish no earlier than 2005-12-15 | R3 | 2608h | 1304h | VHCRTDD-IurIub | Rel-7 | TSG | MCC_RAN | Peter Legg, IPWireless | plegg@ipwireless.com |
| 74 | 20.5 | VHCRTDD: RF Radio Transmission/ Reception, System Performance Requirements and Conformance Testing |  | 456d? | 2004-09-15 A | 2006-06-15 | 35% | 296.4d? | 2004-09-15 | 2006-06-15 | 456d? | 207d | finish no earlier than 2006-06-15 | R4 | 3648h | 1276.8h | VHCRTDD-RF | Rel-7 | TSG | MCC_RAN | Shin Horng Wong | shwong@ipwireless.com |
| 75 | 21 | **Rel-7 RAN improvements** |  | 325d? | 2004-12-15 A | 2006-03-15 | 27% | 238.44d? | 2004-12-15 | 2006-03-15 | 325d? | 273d |  | RP | 8872h | 2362.85h | RANimp | Rel-7 | TSG | Cesar |  |  |
| 76 | 21.1 | Optimisation of channelisation code utilisation for 1.28 Mcps TDD |  | 261d? | 2004-12-15 A | 2005-12-15 | 70% | 78.3d? | 2004-12-15 | 2005-12-15 | 261d? | 337d | finish no earlier than 2005-12-15 | R1 | 2088h | 1461.6h | RANimp-RABSE-CodOptLCRTDD | Rel-7 | TSG | MCC_RAN | Ka Leong Lo | kaleong.lo@utstar.com |
| 77 | 21.2 | Delay optimisation for procedures applicable to CS and PS Connections |  | 261d? | 2005-03-15 | 2006-03-15 |  |  | 2005-03-15 | 2006-03-15 | 261d? | 273d | finish no earlier than 2006-03-15 | R2 | 2088h |  | RANimp-DelayOpt | Rel-7 | TSG | MCC_RAN | Juho Pirskanen | juho.pirskanen@nokia.com |
| 78 | 21.3 | UE Performance Requirements for MBMS (TDD) |  | 261d? | 2005-03-15 A | 2006-03-15 | 10% | 234.9d? | 2005-03-15 | 2006-03-15 | 261d? | 273d | finish no earlier than 2006-03-15 | R4 | 2088h | 208.8h | MBMS-RAN-RF-TDD | Rel-7 | TSG | MCC_RAN | Shin Horng Wong | shwong@ipwireless.com |
| 79 | 21.4 | Continuous connectivity for packet data users |  | 1d? | 2005-03-14 | 2005-03-15 |  |  | 2005-03-14 | 2005-03-15 | 1d? | 534d | finish no earlier than 2005-03-15 | R1 | 8h |  | RANimp-Cont | Rel-7 | TSG | MCC_RAN | Joerg Gustrau | joerg.gustrau@siemens.com |

Notes:
- 55: WI sent to NP#25 for approval / Text3: new TR, 24.229, 29.229, 29.163, 29.209
- 56: Duplicated entry ("ACCSEC2", "Access Security Enhancements", SP-040865) deleted by A.Sultan / Text3: 33.102, 43.020
- 57: WID approved SA#26. Record created after SA#27. It is about improved GERAN security / Text3: 33.102, 43.020
- 58: 27/11/2002 KK: WID approved at CN#18 (NP-020601)........
- 61: Approved at RP#25 as RP-040377 / Text3: TS25.101, TS25.104, TS25.133, TS25.141, TS25.331, TS25.942, TS25.306, TS25.307, TS34.121
- 62: Text3: 25.102, 25.105, 25.113, 25.123, 25.142, 25.331, 25.942, 25.306, 25.307, 34.122, 34.124
- 63: Text3: 25.101, 25.104, 25.113, 25.133, 25.141, 25.331, 25.942, 25.306, 25.307, 34.121
- 64: Text3: 25.101, 25.104, 25.113, 25.133, 25.141, 25.306, 25.307, 25.331, 34.121
- 65: Text3: 25.101, 25.104, 25.133, 25.141, 25.331, 25.942, 25.306, 25.307, 34.121
- 66: Text3: TS25.101
- 67: Text3: 25.101
- 68: Text3: 25.101
- 69: Approved at RP#25 as RP-040365
- 70: Text3: New specification
- 71: Text3: TS25.221, TS25.222, TS25.223, TS25.224,TS25.225
- 72: Text3: TS25.301, TS25.302, TS25.305, TS25.306, TS25.321, TS25.331
- 73: Text3: TS25.401, TS25.420, TS25.423, TS25.425, TS25.427, TS25.430, TS25.433, TS25.435
- 74: Text3: TS25.102, TS25.105, TS25.123, TS25.133, TS25.142
- 75: Generic feature
- 77: Text3: TS25.321, TS25.322, TS25.331
- 78: Text3: TS25.102, TS25.123

| ID | WBS | Task | Type | Duration | Start | Finish | Complete | Remaining | Baseline start | Baseline finish | Baseline duration | Total slack | Constraint | Resources | Work | Actual work | Text1 | Text4 | Text5 | Text6 | Text7 | Text8 |
| --- | --- | --- | --- | --- | --- | --- | --- | --- | --- | --- | --- | --- | --- | --- | --- | --- | --- | --- | --- | --- | --- | --- |
| 80 | 22 | **3.84 Mcps TDD Enhanced Uplink** |  | 327d? | 2005-03-15 A | 2006-06-15 | 16% | 273.1d? | 2005-03-15 | 2006-06-15 | 327d? | 207d |  | RP | 13072h | 2154.83h | EDCHTDD | Nicholas Anderson | nanderson@ipwireless.com | Rel-7 | TSG | Cesar |
| 81 | 22.1 | EDCHTDD: Stage 2 |  | 197d? | 2005-03-15 A | 2005-12-14 | 10% | 177.3d? | 2005-03-15 | 2005-12-14 | 197d? | 337d | start no earlier than 2005-03-15 | R2 | 1576h | 157.6h | EDCHTDD-Stage2 | Nicholas Anderson | nanderson@ipwireless.com | Rel-7 | TSG | MCC_RAN |
| 82 | 22.2 | EDCHTDD: Physical Layer |  | 261d? | 2005-03-15 A | 2006-03-14 | 35% | 169.65d? | 2005-03-15 | 2006-03-14 | 261d? | 273d | start no earlier than 2005-03-15 | R1 | 2088h | 730.8h | EDCHTDD-Phys | Nicholas Anderson | nanderson@ipwireless.com | Rel-7 | TSG | MCC_RAN |
| 83 | 22.3 | EDCHTDD: Layer 2 and 3 Protocol Aspects |  | 261d? | 2005-03-15 A | 2006-03-14 | 35% | 169.65d? | 2005-03-15 | 2006-03-14 | 261d? | 273d | start no earlier than 2005-03-15 | R2 | 2088h | 730.8h | EDCHTDD-L23 | Derek Richards | drichards@ipwireless.com | Rel-7 | TSG | MCC_RAN |
| 84 | 22.4 | EDCHTDD: UTRAN Iub/Iur Protocol Aspects |  | 261d? | 2005-03-15 A | 2006-03-14 | 5% | 247.95d? | 2005-03-15 | 2006-03-14 | 261d? | 273d | start no earlier than 2005-03-15 | R3 | 2088h | 104.4h | EDCHTDD-IurIub | Jim Miller | jim.miller@interdigital.com | Rel-7 | TSG | MCC_RAN |
| 85 | 22.5 | EDCHTDD: RF Radio Transmission/ Reception, System Performance Requirements and Conformance Testing |  | 327d? | 2005-03-15 | 2006-06-15 |  |  | 2005-03-15 | 2006-06-15 | 327d? | 207d | finish no earlier than 2006-06-15 | R4 | 2616h |  | EDCHTDD-RF | Shin Horng Wong | shwong@ipwireless.com | Rel-7 | TSG | MCC_RAN |
| 86 | 23 | **Support of SMS and MMS over generic 3GPP IP access** |  | 432d? | 2004-10-14 A | 2006-06-09 | 40% | 260.59d? | 2004-10-14 | 2006-06-09 | 432d? | 210d |  | S2 | 6944h | 2560.4h | SMSIP | Wenlin Zhang (Huawei) | zhangwenlin@huawei.com | Rel-7 | TSG | Maurice |
| 87 | 23.1 | FS on SMSIP |  | 173d? | 2004-10-14 A | 2005-06-13 A | 100% |  | 2004-10-14 | 2005-06-13 | 173d? |  | start no earlier than 2004-10-14 | S2 | 1384h | 1384h | SMSIP |  |  | Rel-7 |  |  |
| 88 | 23.2 | Stage 2 for SMSIP |  | 263d? | 2005-06-08 | 2006-06-09 |  |  | 2005-06-08 | 2006-06-09 | 263d? | 210d | start no earlier than 2005-06-08 | S2 | 2104h |  | SMSIP |  |  | Rel-7 |  |  |
| 89 | 24 | **Evolution of Policy Control and Charging** |  | 437d? | 2004-10-14 A | 2006-06-16 | 45% | 241.29d? | 2004-10-14 | 2006-06-16 | 437d? | 205d |  | S2 | 10016h | 4180h | PCC |  |  | Rel-7 | TSG | Maurice |
| 90 | 24.1 | TR for PCC |  | 315d? | 2004-10-14 A | 2005-12-29 A | 100% |  | 2004-10-14 | 2005-12-29 | 315d? |  | finish no earlier than 2005-12-28 | S2 | 2520h | 2520h | PCC |  |  | Rel-7 |  |  |
| 91 | 24.2 | Stage 2 for PCC |  | 250d? | 2005-07-04 A | 2006-06-16 | 20% | 200d? | 2005-07-04 | 2006-06-16 | 250d? | 205d | start no earlier than 2005-07-04 | S2 | 2000h | 400h | PCC |  |  | Rel-7 |  |  |
| 92 | 24.3 | Evolution of policy control and flow based bearer level charging |  | 250d? | 2005-07-04 | 2006-06-16 |  |  | 2005-07-04 | 2006-06-16 | 250d? | 205d | start no earlier than 2005-07-04 | S2 | 2000h |  | PCC | Balazs Bertenyi (Nokia) | balazs.bertenyi@nokia.com | Rel-7 |  |  |
| 93 | 25 | Video Codec Performance Requirements |  | 453d? | 2005-01-03 A | 2006-09-27 | 25% | 339.75d? | 2005-01-03 | 2006-09-27 | 453d? | 132d | finish no earlier than 2006-09-27 | S4 | 3624h | 906h | VICPer | Juergen Pandel (Siemens AG) | juergen.pandel@siemens.com | Rel-7 | TSG | Paolo |
| 94 | 26 | DIAMETER on the GGSN Gi interface |  | 266d? | 2004-09-10 | 2005-09-16 |  |  | 2004-09-10 | 2005-09-16 | 266d? | 400d | finish no earlier than 2005-09-16 | C3 | 2128h |  | DIAMGi | Stefan Koppenborg (T-Mobile) | stefan.koppenborg@t-mobile.de | Rel-7 | TSG | Seung Don |
| 95 | 27 | **CAMEL Trunk Triggers** |  | 251d? | 2004-12-17 A | 2005-12-05 | 53% | 119.22d? | 2004-12-17 | 2005-12-05 | 251d? | 344.5d |  | S1 | 6024h | 3162.6h | TTCAMEL | Amar Deol, Nortel Networks | deola@nortelnetworks.com | Rel-7 | TSG | Michael |
| 96 | 27.1 | Stage 1 for CAMEL Trunk Triggers |  | 251d? | 2004-12-17 A | 2005-12-05 | 95% | 12.55d? | 2004-12-17 | 2005-12-05 | 251d? | 344.5d |  | S1 | 2008h | 1907.6h | TTCAMEL | Amar Deol, Nortel Networks | deola@nortelnetworks.com | Rel-7 | TSG | Michael |
| 97 | 27.2 | CAMEL Trunk Originated Trigger Detection Points |  | 251d? | 2004-12-17 A | 2005-12-05 | 10% | 225.9d? | 2004-12-17 | 2005-12-05 | 251d? | 344.5d | start no earlier than 2004-12-17 | C4 | 2008h | 200.8h | CamelR7 | David Hutton, Nortel Networks | dhutton@nortel.com | Rel-7 | TSG | Kimmo |
| 98 | 28 | MS Antenna Performance Evaluation Method and Requirements |  | 206d? | 2005-01-28 A | 2005-11-11 | 10% | 185.4d? | 2005-01-28 | 2005-11-11 | 206d? | 360d | finish no earlier than 2005-11-11 | G1 | 1648h | 164.8h | APEMR | Ulf.Tegth (TeliaSonera) | Ulf.Tegth@teliasonera.com | Rel-7 | TSG | Paolo |
| 99 | 29 | **Lower 700 MHz Inclusion in the GERAN Specifications** |  | 345d? | 2005-01-03 A | 2006-04-28 | 43% | 197.39d? | 2005-01-03 | 2006-04-28 | 345d? | 240d |  | GP | 6552h | 1625.6h | GSM710 | Dave Cotton (UTC) | dcotton@mtview.union-tel.com | Rel-7 | TSG | Paolo |
| 100 | 29.1 | Inclusion of the 698 – 746 MHz band into GERAN core specifications |  | 129d? | 2005-01-03 A | 2005-06-30 A | 100% |  | 2005-01-03 | 2005-06-30 | 129d? |  | finish no earlier than 2005-06-30 | G1 | 1032h | 1032h | GSM710-core |  |  | Rel-7 |  | Paolo |
| 101 | 29.2 | Inclusion of the 698 – 746 MHz band into GERAN test specifications |  | 172.5d? | 2005-08-31 | 2006-04-28 |  |  | 2005-08-31 | 2006-04-28 | 172.5d? | 240d | finish no earlier than 2006-04-28 | G3; G1 | 2760h |  | GSM-710-test |  |  | Rel-7 |  | Stoyan |
| 102 | 30 | **Enhancements of VGCS for public authority officials** |  | 333d? | 2004-08-27 A | 2005-12-06 | 43% | 189.95d? | 2004-08-27 | 2005-12-06 | 333d? | 343d |  | S1 | 7856h | 2230.4h | EVGCS | Siemens |  | Rel-7 | TSG | Andrijana |
| 103 | 30.1 | Stage 1 | milestone | 0d? | 2004-08-27 A | 2004-08-27 A | 100% |  | 2004-08-27 | 2004-08-27 | 0d? |  | finish no earlier than 2004-08-27 | S1 |  |  | EVGCS | Joerg Swetina (Siemens AG) | joerg.swetina@SIEMENS.COM | Rel-7 | TSG | Michael |
| 104 | 30.2 | Architecture and protocol aspects |  | 333d? | 2004-08-27 A | 2005-12-06 | 60% | 133.2d? | 2004-08-27 | 2005-12-06 | 333d? | 343d | start no earlier than 2004-08-27 | C1 | 2664h | 1598.4h | EVGCS |  |  | Rel-7 |  |  |
| 105 | 30.3 | GERAN2 aspects |  | 316d? | 2004-08-27 A | 2005-11-11 | 25% | 237d? | 2004-08-27 | 2005-11-11 | 316d? | 360d | finish no earlier than 2005-11-11 | G2 | 2528h | 632h | EVGCS | Ken Isaacs (Siemens) | kenneth.isaacs@roke.co.uk | Rel-7 | TSG | Gert |

Notes:
- 82: Text3: TS25.201, TS25.221,TS25.222, TS25.223, TS25.224, TS25.225
- 83: Text3: TS25.301, TS25.302, TS25.306, TS25.321, TS25.331
- 84: Text3: TS25.401, TS25.420, TS25.423, TS25.427, TS25.430, TS25.433, TS25.435
- 85: Text3: TS25.102, TS25.105, TS25.123, TS25.142
- 86: Revised at SP#29 / Text3: TR 23.abc, TS 23.abc
- 92: Approved at SP#29. 23.125 will be discontinued from Release 7. / Text3: 23.207, 23.125, 23.002, 23.228
- 93: Text3: 26.234, 26.235, 26.346, 26.140
- 94: Not started
- 97: Not started
- 98: Started / Text3: 25.9xx, 45.005
- 99: Started / Text3: 24.008, 43.022, 44.018, 44.118, 45, 001, 45.005, 51.010, 51.021
- 100: Completed / Text3: 24.008, 43.022, 44.018, 44.118, 45, 001, 45.005,
- 101: Not started / Text3: 51.010, 51.021
- 102: Text3: 43.068, 44.068, 24.008, 29.002
- 103: Text3: 42.068, 43.068
- 104: Text3: 44.068

| ID | WBS | Task | Type | Duration | Start | Finish | Complete | Remaining | Baseline start | Baseline finish | Baseline duration | Total slack | Constraint | Resources | Work | Actual work | Text1 | Text6 | Text4 | Text5 | Text7 | Text8 | Text10 |
| --- | --- | --- | --- | --- | --- | --- | --- | --- | --- | --- | --- | --- | --- | --- | --- | --- | --- | --- | --- | --- | --- | --- | --- |
| 106 | 31 | **Improvements of VGCS for parallel use of services** |  | 194d? | 2005-03-15 A | 2005-12-09 | 18% | 159.05d? | 2005-03-15 | 2005-12-09 | 194d? | 340d |  | S1 | 4230.16h | 573.6h | IVGCS | Rel-7 |  |  |  |  |  |
| 107 | 31.1 | Service Requirements for VGCS improvements |  | 62d? | 2005-03-15 A | 2005-06-08 A | 100% |  | 2005-03-15 | 2005-06-08 | 62d? |  | finish no earlier than 2005-06-08 | S1 | 496h | 496h | IVGCS | Rel-7 | Kurt Bischinger (T-Mobile) | kurt.bischinger@t-mobile.at | TSG | Michael |  |
| 108 | 31.2 | Stage 2 modifications for VGCS improvements |  | 142d? | 2005-03-15 | 2005-09-28 |  |  | 2005-03-15 | 2005-09-28 | 142d? | 392d | finish no earlier than 2005-09-28 | C1 | 1136h |  | IVGCS | Rel-7 | Kurt Bischinger (T-Mobile) | kurt.bischinger@t-mobile.at | TSG |  |  |
| 109 | 31.3 | Architecture and protocol aspects |  | 194d? | 2005-03-15 A | 2005-12-09 | 5% | 184.3d? | 2005-03-15 | 2005-12-09 | 194d? | 340d | finish no earlier than 2005-12-09 | C1 | 1552h | 77.6h | IVGCS | Rel-7 |  |  |  |  |  |
| 110 | 32 | **OSA Rel-7** |  | 142d? | 2005-03-15 A | 2005-09-28 | 20% | 113.95d? | 2005-03-15 | 2005-09-28 | 142d? | 392d |  | S1 | 2768h | 546.82h | OSA7-SB | Rel-7 | Eamonn Murray (AePONA) | eamonn.murray@aepona.com | TSG | Michael |  |
| 111 | 32.1 | Service Requirements for OSA Service Broker |  | 62d? | 2005-03-15 A | 2005-06-08 | 65% | 21.7d? | 2005-03-15 | 2005-06-08 | 62d? | 472d | finish no earlier than 2005-06-08 | S1 | 496h | 322.4h | OSA7-SB | Rel-7 | Eamonn Murray (AePONA) | eamonn.murray@aepona.com | TSG | Michael |  |
| 112 | 32.2 | Stage 2 modifications for OSA Service Broker |  | 142d? | 2005-03-15 | 2005-09-28 |  |  | 2005-03-15 | 2005-09-28 | 142d? | 392d | finish no earlier than 2005-09-28 | C5 | 1136h |  | OSA7-SB | Rel-7 | Eamonn Murray (AePONA) | eamonn.murray@aepona.com | TSG | Adrian |  |
| 113 | 33 | Dynamic and interactive multimedia scenes |  | 402d? | 2005-03-15 A | 2006-09-27 | 20% | 321.6d? | 2005-03-15 | 2006-09-27 | 402d? | 132d | finish no earlier than 2006-09-27 | S4 | 3216h | 643.2h | DIMS | Rel-7 | Gaëlle MARTIN-COCHER (Streamezzo) | gaelle.martin-cocher@streamezzo.com | TSG | Paolo |  |
| 114 | 34 | Liberty Alliance and 3GPP Security Interworking |  | 147d? | 2005-03-10 A | 2005-09-30 | 10% | 132.3d? | 2005-03-10 | 2005-09-30 | 147d? | 390d | finish no earlier than 2005-09-30 | S3 | 1176h | 117.6h | LibSec | Rel-7 | Silke Holtmanns, Nokia | Silke.Holtmanns@NOKIA.COM | TSG | Maurice |  |
| 115 | 35 | **WLAN-UMTS Interworking Phase 2** |  | 371d? | 2004-01-05 A | 2005-06-07 | 99% | 0d? | 2004-01-05 | 2005-06-07 | 371d? | 474d |  | S1 | 3888h | 3888h |  | Rel-7 | Fredric Paint, Telenor | frederic.paint@telenor.com | TSG | Michael |  |
| 116 | 35.1 | Stage 1 on Session Continuity |  | 115d? | 2004-01-05 A | 2004-06-11 A | 100% |  | 2004-01-05 | 2004-06-11 | 115d? |  | start no earlier than 2004-01-05 | S1 | 920h | 920h | WLAN-SC | Rel-7 |  |  |  |  | SP-24 |
| 117 | 35.2 | Stage 2 on Session Continuity: covered by SAE | milestone | 0d? | 2005-06-07 | 2005-06-07 |  |  | 2005-06-07 | 2005-06-07 | 0d? | 474d | finish no earlier than 2005-06-07 | S2 |  |  |  | Rel-7 |  |  |  |  |  |
| 118 | 36 | **Voice call continuity between CS and IMS (incl. I-WLAN)** |  | 386d? | 2004-12-31 A | 2006-06-23 | 27% | 282.56d? | 2004-12-31 | 2006-06-23 | 386d? | 200d |  | S2 | 8208h | 2142.4h | VCC | Rel-7 | Andy Bennett, Lucent; Roger Bunting, Cingular | andybennett@lucent.com |  | Maurice |  |
| 119 | 36.1 | TR for VCC |  | 245d? | 2004-12-31 A | 2005-12-08 | 70% | 73.5d? | 2004-12-31 | 2005-12-08 | 245d? | 341d | finish no earlier than 2005-12-08 | S2 | 1960h | 1372h | VCC | Rel-7 |  |  |  |  |  |
| 120 | 36.2 | Stage 2 for VCC |  | 199d? | 2005-09-06 | 2006-06-09 |  |  | 2005-09-06 | 2006-06-09 | 199d? | 210d | finish no earlier than 2006-06-09 | S2 | 1592h |  | VCC | Rel-7 |  |  |  |  |  |
| 121 | 36.3 | Stage 3 for VCC |  | 196d? | 2005-09-23 | 2006-06-23 |  |  | 2005-09-23 | 2006-06-23 | 196d? | 200d | finish no earlier than 2006-06-23 | C1 | 1568h |  | VCC | Rel-7 |  |  |  |  |  |
| 122 | 37 | DIAMETER on the PDG Wi inteface |  | 266d? | 2004-09-10 | 2005-09-16 |  |  | 2004-09-10 | 2005-09-16 | 266d? | 400d | finish no earlier than 2005-09-16 | C3 | 2128h |  | DIAMWi | Rel-7 | Stefan Koppenborg (T-Mobile) | stefan.koppenborg@t-mobile.de | TSG | Seung Don |  |
| 123 | 38 | **OAM&P** |  | 815d? | 2004-02-16 A | 2007-03-30 | 9% | 743.06d? | 2004-02-16 | 2007-03-30 | 815d? | 0d |  | S5 | 65161.1h | 8280.91h | OAM7 | Rel-7 | Christian TOCHE | toche@nortel.com | TSG | Adrian |  |
| 124 | 38.1 | **Network Infrastructure Management** |  | 341d? | 2005-09-02 A | 2006-12-22 | 9% | 310.04d? | 2005-09-02 | 2006-12-22 | 341d? | 70d |  | S5 | 30568h | 2528.02h | OAM7-NIM | Rel-7 | Christian TOCHE | toche@nortel.com |  |  |  |
| 125 | 38.1.1 | Enhance NRM to accommodate NGN (IMS as basis of the Next Generation Network) |  | 341d? | 2005-09-02 A | 2006-12-22 | 5% | 323.95d? | 2005-09-02 | 2006-12-22 | 341d? | 70d | finish no earlier than 2006-12-22 | S5 | 2728h | 136.4h | OAM7-NIM-NGN | Rel-7 | BT |  |  |  |  |
| 126 | 38.1.2 | IRP usage scenarios |  | 69d? | 2005-09-02 A | 2005-12-07 | 5% | 65.55d? | 2005-09-02 | 2005-12-07 | 69d? | 342d | finish no earlier than 2005-12-07 | S5 | 552h | 27.6h | OAM7-NIM | Rel-7 | Lucent |  |  |  |  |
| 127 | 38.1.3 | Co-operative Element Management interface (CO-OP) |  | 151d? | 2005-09-02 A | 2006-03-31 | 50% | 75.5d? | 2005-09-02 | 2006-03-31 | 151d? | 260d | finish no earlier than 2006-03-31 | S5 | 1208h | 604h | OAM7-NIM-COOP | Rel-7 | Motorola |  |  |  |  |
| 128 | 38.1.4 | Network Management (NM) Itf-N performance criteria |  | 69d? | 2005-09-02 A | 2005-12-07 | 5% | 65.55d? | 2005-09-02 | 2005-12-07 | 69d? | 342d | finish no earlier than 2005-12-07 | S5 | 552h | 27.6h | OAM7-NIM | Rel-7 | China Mobile |  |  |  |  |
| 129 | 38.1.5 | Delta synchronization between IRP Manager and IRP Agent |  | 69d? | 2005-09-02 A | 2005-12-07 | 30% | 48.3d? | 2005-09-02 | 2005-12-07 | 69d? | 342d | finish no earlier than 2005-12-07 | S5 | 552h | 165.6h | OAM7-NIM | Rel-7 | Siemens |  |  |  |  |
| 130 | 38.1.6 | Subscription Management (SuM) IRP Solution Sets |  | 151d? | 2005-09-02 A | 2006-03-31 | 40% | 90.6d? | 2005-09-02 | 2006-03-31 | 151d? | 260d | finish no earlier than 2006-03-31 | S5 | 1208h | 483.2h | OAM7-NIM-SuM | Rel-7 | T-Mobile |  |  |  |  |
| 131 | 38.1.7 | Integration Reference Point (IRP) Security Management |  | 216d? | 2005-09-02 A | 2006-06-30 | 10% | 194.4d? | 2005-09-02 | 2006-06-30 | 216d? | 195d | finish no earlier than 2006-06-30 | S5 | 1728h | 172.8h | OAM7-NIM | Rel-7 | Huawei |  |  |  |  |
| 132 | 38.1.8 | Integration Reference Point (IRP) Methodology |  | 330d? | 2005-09-02 A | 2006-12-07 | 5% | 313.5d? | 2005-09-02 | 2006-12-07 | 330d? | 81d | finish no earlier than 2006-12-07 | S5 | 2640h | 132h | OAM7-NIM | Rel-7 | Ericsson |  |  |  |  |
| 133 | 38.1.9 | Partial suspension of Itf-N during maintenance/testing |  | 69d? | 2005-09-02 A | 2005-12-07 | 15% | 58.65d? | 2005-09-02 | 2005-12-07 | 69d? | 342d | finish no earlier than 2005-12-07 | S5 | 552h | 82.8h | OAM7-NIM | Rel-7 | Siemens |  |  |  |  |
| 134 | 38.1.10 | Advanced Alarming on Itf-N |  | 216d? | 2005-09-02 A | 2006-06-30 | 25% | 162d? | 2005-09-02 | 2006-06-30 | 216d? | 195d | finish no earlier than 2006-06-30 | S5 | 1728h | 432h | OAM7-NIM | Rel-7 | Siemens |  |  |  |  |
| 135 | 38.1.11 | Management of Legacy Equipment |  | 69d? | 2005-09-02 A | 2005-12-07 | 5% | 65.55d? | 2005-09-02 | 2005-12-07 | 69d? | 342d | finish no earlier than 2005-12-07 | S5 | 552h | 27.6h | OAM7-NIM | Rel-7 | Siemens |  |  |  |  |
| 136 | 38.1.12 | Rules for Vendor Specific Extensions |  | 151d? | 2005-09-02 A | 2006-03-31 | 5% | 143.45d? | 2005-09-02 | 2006-03-31 | 151d? | 260d | finish no earlier than 2006-03-31 | S5 | 1208h | 60.4h | OAM7-NIM | Rel-7 | Siemens |  |  |  |  |
| 137 | 38.1.13 | CN CS Bearer Transport Network (BTN) relative NRM |  | 69d? | 2005-09-02 A | 2005-12-07 | 10% | 62.1d? | 2005-09-02 | 2005-12-07 | 69d? | 342d | finish no earlier than 2005-12-07 | S5 | 552h | 55.2h | OAM7-NIM | Rel-7 | China Mobile |  |  |  |  |
| 138 | 38.1.14 | NEW Backward and Forward Compatibility of IRP systems |  | 341d? | 2005-09-02 A | 2006-12-22 | 1% | 337.59d? | 2005-09-02 | 2006-12-22 | 341d? | 70d | start no earlier than 2005-09-02 | S5 | 2728h | 27.28h | OAM7-NIM-BFC | Rel-7 | Ericsson |  |  |  |  |
| 139 | 38.1.15 | NEW Study of Element Operations Systems Function (EOSF) definition |  | 341d? | 2005-09-02 A | 2006-12-22 | 1% | 337.59d? | 2005-09-02 | 2006-12-22 | 341d? | 70d | start no earlier than 2005-09-02 | S5 | 2728h | 27.28h | OAM7-NIM- EOSF | Rel-7 | China Mobile |  |  |  |  |
| 140 | 38.1.16 | NEW Study of SOAP/HTTP IRP Solution Sets |  | 276d? | 2005-09-02 A | 2006-09-22 | 1% | 273.24d? | 2005-09-02 | 2006-09-22 | 276d? | 135d | finish no earlier than 2006-09-22 | S5 | 2208h | 22.08h | OAM7-NIM-SOAP | Rel-7 | Nortel |  |  |  |  |
| 141 | 38.1.17 | NEW Study of Itf-N Implementation Conformance Statement (ICS) template |  | 276d? | 2005-09-02 A | 2006-09-22 | 1% | 273.24d? | 2005-09-02 | 2006-09-22 | 276d? | 135d | start no earlier than 2005-09-02 | S5 | 2208h | 22.08h | OAM7-NIM-ICS | Rel-7 | China Mobile |  |  |  |  |
| 142 | 38.1.18 | NEW Study of IRP Information Model |  | 276d? | 2005-09-02 A | 2006-09-22 | 1% | 273.24d? | 2005-09-02 | 2006-09-22 | 276d? | 135d | start no earlier than 2005-09-02 | S5 | 2208h | 22.08h | OAM7-NIM-IM | Rel-7 | Motorola |  |  |  |  |

Notes:
- 107: "completeed" as from Chris S' e-mail / Text3: 42.068
- 108: Text3: 43.068
- 109: Text3: 44.068
- 111: Text3: 22.127
- 112: Text3: 23.198
- 113: Started / Text3: 26.234, 23.346, 26.140, 26.244
- 114: WID approved SA#27.
- 115: Created at TSG#27 by A. Sultan because of WLAN items belonging to Rel-7
- 118: WID approved SA#27. Revised at SA#28. / Text3: 22.101, 22.228, 23.228
- 121: Text3: new TS, 24.229, 23.008, 23.009, 23.078, 29.078, 29.163, 29.228, 29.229, 29.230, 29.278, 29.328, 29.329
- 122: Not started
- 123: Created at TSG#27 by A. Sultan due to the split of the OAM BB Trace Rel-6/Rel-7 / Text3: see WT WIDs
- 124: SA#28 (06/2005) created / Text3: see WT WIDs
- 125: SA#28 (06/2005) created / Text3: 32.632, 32.633, 32.634, 32.635
- 126: SA#28 (06/2005) created. 09/05 Changed title to Study / Text3: new TR 32.8xy
- 127: SA#28 (06/2005) created. 09/05 Changed title to Study / Text3: new TR 32.8xy, 32.101
- 128: SA#28 (06/2005) created. 09/05 Changed title to Study / Text3: new TS 32.yzx
- 129: SA#28 (06/2005) created. 09/05 Changed title to Study / Text3: new TR 32.8xy,new TSs 32.111-n,32.60n; For n = 1 to 5
- 130: SA#28 (06/2005) created / Text3: 32.101,32.175, new TSs 32.161,32.307,32.317,32.607,32.617,32.667
- 131: SA#28 (06/2005) created / Text3: New TSs 32.372,32.373,32.374; 32.111,32.30x,32.32x,32.33x,32.34x,32.35x,32.36x,32.41x,32.60x,32.61x,32.66x
- 132: SA#28 (06/2005) created / Text3: New TSs 32.15w,32.15x,32.15y,32.15z; 32.150,32.151,32.152
- 133: SA#28 (06/2005) created. 09/05 Changed title to Study / Text3: new TR 32.8xy, new TSs 32.30n,32.60n,32.61n; For n = 1 to 5
- 134: SA#28 (06/2005) created. 09/05 Changed title to Study / Text3: new TR 32.8xy ; New TSs 32.111-n,32.30n; For n = 1 to 5
- 135: SA#28 (06/2005) created. 09/05 Changed title to Study / Text3: new TS 32.xxx, New TSs 32.62n,32.63n,32.64n,32.65n,32.71n,32.74n,32.69n; For n = 1 to 5
- 136: SA#28 (06/2005) created / Text3: 32.62n; For n = 1 to 5
- 137: SA#28 (06/2005) created / Text3: New Tss TS 32.xx1,TS 32.xx2,TS 32.xx3,TS 32.xx4
- 138: SA#29 (09/2005) created / Text3: TR 32.805. new TS 32.15X
- 139: SA#29 (09/2005) created / Text3: new TR 32.8xy
- 140: SA#29 (09/2005) created / Text3: new TR 32.8xy
- 141: SA#29 (09/2005) created / Text3: new TR 32.8xy
- 142: SA#29 (09/2005) created / Text3: new TR 32.8xy

| ID | WBS | Task | Duration | Start | Finish | Complete | Remaining | Baseline start | Baseline finish | Baseline duration | Total slack | Constraint | Resources | Work | Actual work | Text1 | Text4 | Text5 | Text6 | Text7 | Text8 |
| --- | --- | --- | --- | --- | --- | --- | --- | --- | --- | --- | --- | --- | --- | --- | --- | --- | --- | --- | --- | --- | --- |
| 143 | 38.2 | **Performance Management** | 346d? | 2005-09-02 A | 2006-12-29 | 14% | 298.65d? | 2005-09-02 | 2006-12-29 | 346d? | 65d |  | S5 | 11128h | 1144.08h | OAM7-PM | Christian TOCHE | toche@nortel.com | Rel-7 |  |  |
| 144 | 38.2.1 | Performance measurements definition for CN CS | 151d? | 2005-09-02 A | 2006-03-31 | 10% | 135.9d? | 2005-09-02 | 2006-03-31 | 151d? | 260d | finish no earlier than 2006-03-31 | S5 | 1208h | 120.8h | OAM7-PM | China Mobile |  | Rel-7 |  |  |
| 145 | 38.2.2 | Enhancement UTRAN performance measurements definition | 69d? | 2005-09-02 A | 2005-12-07 | 10% | 62.1d? | 2005-09-02 | 2005-12-07 | 69d? | 342d | finish no earlier than 2005-12-07 | S5 | 552h | 55.2h | OAM7-PM | China Mobile |  | Rel-7 |  |  |
| 146 | 38.2.3 | Add TDD specific counters in Performance measurement | 346d? | 2005-09-02 A | 2006-12-29 | 30% | 242.2d? | 2005-09-02 | 2006-12-29 | 346d? | 65d | finish no earlier than 2006-12-29 | S5 | 2768h | 830.4h | OAM7-PM | CATT |  | Rel-7 |  |  |
| 147 | 38.2.4 | ATM bearer network Performance measurements | 69d? | 2005-09-02 A | 2005-12-07 | 10% | 62.1d? | 2005-09-02 | 2005-12-07 | 69d? | 342d | finish no earlier than 2005-12-07 | S5 | 552h | 55.2h | OAM7-PM | ZTE |  | Rel-7 |  |  |
| 148 | 38.2.5 | IP bearer network Performance measurement definitions | 69d? | 2005-09-02 A | 2005-12-07 | 10% | 62.1d? | 2005-09-02 | 2005-12-07 | 69d? | 342d | finish no earlier than 2005-12-07 | S5 | 552h | 55.2h | OAM7-PM | China Mobile |  | Rel-7 |  |  |
| 149 | 38.2.6 | NEW Performance measurements definition for IMS | 341d? | 2005-09-02 A | 2006-12-22 | 1% | 337.59d? | 2005-09-02 | 2006-12-22 | 341d? | 70d | finish no earlier than 2006-12-22 | S5 | 2728h | 27.28h | OAM7-PM-IMS | China Mobile |  | Rel-7 |  |  |
| 150 | 44.5 | **Trace Management** | 815d? | 2004-02-16 A | 2007-03-30 | 5% | 775.71d? | 2004-02-16 | 2007-03-30 | 815d? | 0d |  | S5 | 16945.1h | 816.8h | OAM7-Trace | Christian TOCHE | toche@nortel.com | Rel-7 | TSG |  |
| 151 | 38.3.1 | Trace Management for IMS | 154d? | 2005-05-09 A | 2005-12-08 | 5% | 146.3d? | 2005-05-09 | 2005-12-08 | 154d? | 341d | finish no earlier than 2005-12-08 | S5 | 1232h | 61.6h | OAM7-Trace-IMS | Nortel |  | Rel-7 | TSG |  |
| 152 | 38.3.2 | SIP enhancements for trace | 603.14d? | 2004-02-16 A | 2006-06-16 | 2% | 591.08d? | 2004-02-16 | 2006-06-16 | 603.14d? | 205d | finish no earlier than 2006-06-16 | C1 | 4825.12h | 96.5h | Trace-SIP |  |  | Rel-7 |  |  |
| 153 | 38.3.3 | End-to-end Service Level tracing for IMS | 166d? | 2005-11-11 A | 2006-06-30 | 1% | 164.34d? | 2005-11-11 | 2006-06-30 | 166d? | 195d | start no earlier than 2005-11-11 | S5 | 1328h | 13.28h | OAM7-Trace-IMS | Vodafone |  | Rel-7 | TSG |  |
| 154 | 38.3.4 | IRP for Subscriber and Equipment Trace Management | 411d? | 2005-09-02 A | 2007-03-30 | 1% | 406.89d? | 2005-09-02 | 2007-03-30 | 411d? | 0d | finish no earlier than 2007-03-30 | S5 | 3288h | 32.88h | OAM7-Trace-IRP | Nortel |  | Rel-7 | TSG |  |
| 155 | 38.3.5 | Trace record content for UTRAN TDD | 154d? | 2005-05-09 A | 2005-12-08 | 30% | 107.8d? | 2005-05-09 | 2005-12-08 | 154d? | 341d | finish no earlier than 2005-12-08 | S5 | 1232h | 369.6h | OAM7-Trace-TDD | CATT |  | Rel-7 | TSG |  |
| 156 | 39 | Trust Requirements for Open Platforms in 3GPP | 115d? | 2005-01-03 A | 2005-06-10 | 10% | 103.5d? | 2005-01-03 | 2005-06-10 | 115d? | 470d | finish no earlier than 2005-06-10 | S3 | 920h | 92h | TrustOP | Selim Aissi, Sundeep Bajikar, Intel Corporation | selim.aissi@intel.com; sundeep.bajikar@intel.com | Rel-7 | TSG | Michael |
| 157 | 40 | Development of UEA2 and UIA2 | 268d? | 2004-12-01 A | 2005-12-09 | 50% | 134d? | 2004-12-01 | 2005-12-09 | 268d? | 340d | finish no earlier than 2005-12-09 | S3 | 2144h | 1072h | AlgUEA2 | Per Christoffersson, Teliasonera | per.christoffersson@teliasonera.com | Rel-7 | TSG | Michael |
| 158 | 41 | Lawful Interception in the 3GPP Rel-7 architecture | 118d? | 2005-06-28 A | 2005-12-08 | 5% | 112.1d? | 2005-06-28 | 2005-12-08 | 118d? | 341d | start no earlier than 2005-06-28 | S3 | 944h | 47.2h | LI-7A | Berthold Wilhelm, BMWI | berthold.wilhelm@regtp.de | Rel-7 |  | Mike |
| 159 | 42 | **Support of Conversational Services in A/Gb mode via the PS domain** | 276d? | 2005-04-08 A | 2006-04-28 |  | 276d? | 2005-04-08 | 2006-04-28 | 276d? | 240d |  | GP | 8611.2h | 198.72h | SCSAGB | Gunnar Hedby, Ericsson | gunnar.hedby@ericsson.com | Rel-7 |  | Paolo |
| 160 | 42.1 | Definition of radio resource management functionality | 276d? | 2005-04-08 | 2006-04-28 |  |  | 2005-04-08 | 2006-04-28 | 276d? | 240d | finish no earlier than 2006-04-28 | G1 | 2208h |  | SCSAGB-RRM | Gunnar Hedby, Ericsson | gunnar.hedby@ericsson.com | Rel-7 |  | Paolo |
| 161 | 42.2 | Radio Channel Support | 276d? | 2005-04-08 | 2006-04-28 |  |  | 2005-04-08 | 2006-04-28 | 276d? | 240d | finish no earlier than 2006-04-28 | G2 | 2208h |  | SCSAGB-RCHS | Gunnar Hedby, Ericsson | gunnar.hedby@ericsson.com | Rel-7 |  | Gert |
| 162 | 42.3 | Modifications to FLO | 276d? | 2005-04-08 | 2006-04-28 |  |  | 2005-04-08 | 2006-04-28 | 276d? | 240d | finish no earlier than 2006-04-28 | G2 | 2208h |  | SCSAGB-FLO | Gunnar Hedby, Ericsson | gunnar.hedby@ericsson.com | Rel-7 |  | Gert |
| 163 | 43 | **Addition of new frequency band to GSM (T-GSM810)** | 161d? | 2005-04-08 A | 2005-11-18 | 28% | 115.25d? | 2005-04-08 | 2005-11-18 | 161d? | 355d |  | GP | 4272h | 848h | T-GSM810 | Chen De, Huawei | chende@huawei.com | Rel-7 |  | Paolo |
| 164 | 43.1 | Changes to core specification | 106d? | 2005-04-08 A | 2005-09-02 A | 100% |  | 2005-04-08 | 2005-09-02 | 106d? |  | finish no earlier than 2005-09-02 | GP | 848h | 848h | T-GSM810-Core | Chen De, Huawei | chende@huawei.com | Rel-7 |  | Paolo |
| 165 | 43.2 | Changes to MS testing specification | 161d? | 2005-04-08 | 2005-11-18 |  |  | 2005-04-08 | 2005-11-18 | 161d? | 355d | finish no earlier than 2005-11-18 | G3 | 1288h |  | T-GSM810-Mstest | Chen De, Huawei | chende@huawei.com | Rel-7 |  | Stoyan |
| 166 | 43.3 | Changes to BTS testing specification | 106d? | 2005-04-08 | 2005-09-02 |  |  | 2005-04-08 | 2005-09-02 | 106d? | 410d | finish no earlier than 2005-09-02 | G1 | 848h |  | T-GSM810-BTStest | Chen De, Huawei | chende@huawei.com | Rel-7 |  | Paolo |

Notes:
- 143: SA#28 (06/2005) created / Text3: see WT WIDs
- 144: Text3: New TS 32.xyz
- 145: Text3: 32.403
- 146: SA#28 (06/2005) created / Text3: 32.403
- 147: SA#28 (06/2005) created / Text3: 32.403
- 148: SA#28 (06/2005) created / Text3: 32.403
- 149: SA#29 (09/2005) created / Text3: new TS 32.xyz
- 150: TSG#27: SA5 BB WID to add Trace for IMS (SIP) CN1 24.229 has IETF dependency / Text3: see WT WIDs
- 151: Text3: 32.421,32.422,32.423
- 153: 07/2005: OMA (Stage 1), Stage 2/3 SA5, CT1/3/4 / Text3: 32.101,32.421,32.422,32.423
- 154: SA#29 (09/2005) created / Text3: 32.421,32.422,32.423. 3 new TS 32.4x1,2,3
- 155: Text3: 32.421,32.422,32.423
- 156: WID approved SA#26. Record created after SA#27
- 157: WID approved SA#26, Dependant on Funding Availability. Record created after SA#27 / Text3: 33.102
- 159: Originally started Nov. 2003 as GP-030443
- 160: Not started (PS HO must be completed first)
- 161: Not started (PS HO must be completed first)
- 162: Not started (PS HO must be completed first)
- 163: Text3: 45.005, 45.050, 24.008, 45.008, 45.001, 43.022, 43.030, 44.018, 44.060, 51.010-1, 51.021
- 164: Text3: 45.005, 45.050, 24.008, 45.008, 45.001, 43.022, 43.030, 44.018, 44.060
- 165: Text3: 51010-1
- 166: Text3: 51021

| ID | WBS | Task | Type | Duration | Start | Finish | Complete | Remaining | Baseline start | Baseline finish | Baseline duration | Total slack | Constraint | Resources | Work | Actual work | Text1 | Text4 | Text5 | Text6 | Text8 | Text3 | Text7 |
| --- | --- | --- | --- | --- | --- | --- | --- | --- | --- | --- | --- | --- | --- | --- | --- | --- | --- | --- | --- | --- | --- | --- | --- |
| 167 | 44 | **Handover of dedicated and shared resources while in dual transfer mode** |  | 421d? | 2005-04-08 A | 2006-11-17 | 6% | 395.99d? | 2005-04-08 | 2006-11-17 | 421d? | 95d |  | GP | 8944h | 331.2h | HO-DSRDTM | Rami Vaittinen, Nokia | rami.vaittinen@nokia.com | Rel-7 | Paolo |  |  |
| 168 | 44.1 | Handover of dedicated and shared resources while in dual transfer mode |  | 276d? | 2005-04-08 A | 2006-04-28 | 15% | 234.6d? | 2005-04-08 | 2006-04-28 | 276d? | 240d | finish no earlier than 2006-04-28 | G2 | 2208h | 331.2h | HO-DSRDTM | Rami Vaittinen, Nokia | rami.vaittinen@nokia.com | Rel-7 | Gert | 43.055, 44.018, 44.060 |  |
| 169 | 44.2 | BTS conformance testing |  | 421d? | 2005-04-08 | 2006-11-17 |  |  | 2005-04-08 | 2006-11-17 | 421d? | 95d | finish no earlier than 2006-11-17 | G1 | 3368h |  | HO-DSRDTM-BTStest | Rami Vaittinen, Nokia | rami.vaittinen@nokia.com | Rel-7 | Paolo | 51.026 |  |
| 170 | 45 | Future GERAN Evolution |  | 156d? | 2005-04-08 A | 2005-11-11 | 60% | 62.4d? | 2005-04-08 | 2005-11-11 | 156d? | 360d | finish no earlier than 2005-11-11 | GP | 1248h | 748.8h | FGE | Eddie Riddington, Nokia Corporation | eddie.riddington@nokia.com | Rel-7 | Paolo |  |  |
| 171 | 46 | 3G-324M Video Telephony Call Setup Times Improvements |  | 341d? | 2005-06-08 A | 2006-09-27 | 40% | 204.6d? | 2005-06-08 | 2006-09-27 | 341d? | 132d | finish no earlier than 2006-09-27 | S4 | 2728h | 1091.2h | VTCSTI | Edward Hall (Vodafone) | edward.hall@vodafone.co.uk | Rel-7 | Paolo | 26.abc |  |
| 172 | 47 | Personal Network (PN) and Personal Area Network (PAN) |  | 101.2d? | 2005-07-11 | 2005-12-08 |  |  | 2005-07-11 | 2005-12-08 | 101.2d? | 341d | finish no earlier than 2005-12-08 | S1 | 809.6h |  | PNPAN | Armin Toepfer, Vodafone | armin.toepfer@vodafone.com | Rel-7 | Mike |  |  |
| 173 | 48 | Multimedia Telephony Capabilities for IMS |  | 101.2d? | 2005-07-11 | 2005-12-08 |  |  | 2005-07-11 | 2005-12-08 | 101.2d? | 341d | finish no earlier than 2005-12-08 | S1 | 809.6h |  | MITE | Peter Bleckert, Ericsson | peter.bleckert @ericsson.com | Rel-7 | Mike |  |  |
| 174 | 49 | Transferring of emergency Call data |  | 109d? | 2005-07-11 | 2005-12-08 |  |  | 2005-07-11 | 2005-12-08 | 109d? | 341d | finish no earlier than 2005-12-08 | S1 | 872h |  | eCALL | Steve Vardy, (Motorola S.A.S) | steven.vardy@motorola.com | Rel-7 | Mike |  |  |
| 175 | 50 | MBMS Enhancements |  | 109d? | 2005-07-11 | 2005-12-08 |  |  | 2005-07-11 | 2005-12-08 | 109d? | 341d | finish no earlier than 2005-12-08 | S1 | 872h |  | MBMSE | Liu Hong, China Mobile | liuhongyfw@chinamobile.com | Rel-7 | Mike |  |  |
| 176 | 51 | **Identification of Communication Services in IMS** |  | 355d? | 2005-05-02 A | 2006-09-08 | 30% | 249.71d? | 2005-05-02 | 2006-09-08 | 355d? | 145d |  | S2 | 5656h | 963.2h | ServID | Stephen Terrill, Ericsson | stephen.terrill@ericsson.com | Rel-7 | Maurice | 23.228, 23.218, 23.125 |  |
| 177 | 51.1 | TR for ICS |  | 232d? | 2005-05-02 A | 2006-03-21 | 45% | 127.6d? | 2005-05-02 | 2006-03-21 | 232d? | 268d | finish no earlier than 2006-03-20 | S2 | 1856h | 835.2h | ServID |  |  | Rel-7 |  |  |  |
| 178 | 51.2 | Stage 2 for ICS |  | 120d? | 2006-03-27 | 2006-09-08 |  |  | 2006-03-27 | 2006-09-08 | 120d? | 145d | finish no earlier than 2006-09-08 | S2 | 960h |  | ServID |  |  | Rel-7 |  |  |  |
| 179 | 52 | **VoIMS bearer related enhancements** |  | 354d? | 2005-03-15 A | 2006-07-21 | 20% | 284.84d? | 2005-03-15 | 2006-07-21 | 354d? | 180d |  | S2 | 8959.2h | 1217.6h | VoIMS |  |  | Rel-7 |  |  |  |
| 180 | 52.1 | FS on enhancement of radio performance for VoIMS |  | 320d? | 2005-05-02 A | 2006-07-21 | 25% | 240d? | 2005-05-02 | 2006-07-21 | 320d? | 180d | finish no earlier than 2006-07-21 | S2 | 2560h | 640h | VoIMS | Laurence Lautier, Nortel Networks | lautierl@nortel.com | Rel-7 | Maurice |  |  |
| 181 | 52.2 | Improved support of IMS Realtime Services using HSDPA/HSUPA |  | 197d? | 2005-03-15 A | 2005-12-14 | 30% | 137.9d? | 2005-03-15 | 2005-12-14 | 197d? | 337d | start no earlier than 2005-03-15 | R2 | 1576h | 472.8h | RANimp-IMSRealTime | Don Zelmer | don.zelmer@CINGULAR.COM | Rel-7 | MCC_RAN |  | TSG |
| 182 | 52.3 | Performance Characterization of VoIMS over HSDPA\EUL channels |  | 262d? | 2005-03-15 A | 2006-03-15 | 5% | 248.9d? | 2005-03-15 | 2006-03-15 | 262d? | 272d | finish no earlier than 2006-03-15 | S4 | 2096h | 104.8h | VoIMS-PCVoIMS | Dimitris Vasilaras (Lucent Technologies) | dvasilaras@lucent.com | Rel-7 | Paolo | 26.935 | TSG |
| 183 | 53 | **Optimizations for Multimedia Telephony over IMS** |  | 261d? | 2005-09-28 | 2006-09-27 |  |  | 2005-09-28 | 2006-09-27 | 261d? | 132d |  | S4 | 4176h |  | OMTIMS | Olle Franceschi (Ericsson) | olle.franceschi@ericsson.com | Rel-7 | Paolo | 26.235, 26.236 |  |
| 184 | 53.1 | Characterisation of Adaptive Jitter Management Performance for VoIP Services |  | 261d? | 2005-09-28 | 2006-09-27 |  |  | 2005-09-28 | 2006-09-27 | 261d? | 132d | finish no earlier than 2006-09-27 | S4 | 2088h |  | OMTIMS-CAJMP | David Huo (Lucent Technologies) | dhuo@lucent.com | Rel-7 | Paolo |  |  |
| 185 | 54 | End-to-End Multimedia Services Performance Metrics |  | 261d? | 2005-09-28 | 2006-09-27 |  |  | 2005-09-28 | 2006-09-27 | 261d? | 132d | finish no earlier than 2006-09-27 | S4 | 2088h |  | E2EMSPM | Zhang Yan (China Mobile) | zhangyanyf@chinamobile.com | Rel-7 | Paolo |  |  |
| 186 | 55 | **WLAN Interworking – Private Network access from WLAN 3GPP IP Access** |  | 270d? | 2005-10-10 A | 2006-10-20 |  | 270d? | 2005-10-10 | 2006-10-20 | 270d? | 115d |  | S2 | 2620.97h |  | WLAN-PNA |  |  | Rel-7 | Maurice |  |  |
| 187 | 55.1 | WLAN-PNA - Stage 2 |  | 121.31d? | 2005-10-10 A | 2006-06-23 |  | 121.31d? | 2005-10-10 | 2006-06-23 | 121.31d? | 200d | finish no earlier than 2006-06-23 | S2 | 970.48h |  | WLAN-PNA | Toshiyuki Tamura (NEC) | tamurato@aj.jp.nec.com | Rel-7 | Maurice | 23.234, 33.234 | TSG |
| 188 | 55.2 | WLAN-PNA - Stage 3 |  | 206.31d? | 2005-10-10 A | 2006-10-20 |  | 206.31d? | 2005-10-10 | 2006-10-20 | 206.31d? | 115d |  | C1 | 1650.48h |  | WLAN-PNA | Pierre-Jean Muller (NEC) | pierre-jean.muller@nectech.fr | Rel-7 | Andrijana | 24.234, 29.161, 29.234 | TSG |
| 189 | 56 | Supporting Globally Routable User Agent URIs in IMS | milestone | 0d? | 2005-10-10 A | 2006-10-20 |  | 0d? | 2005-10-10 | 2006-10-20 | 0d? | 115d | finish no earlier than 2006-06-23 | S2 |  |  | GRUU | Adrian Buckley (Research In Motion) | abuckley@rim.com | Rel-7 | Maurice | 23.8XX, 22.228, 23.228, 23.218, 24.229 |  |
| 190 | 57 | ISIM API for Java Card |  | 200d? | 2005-03-14 | 2005-12-16 |  |  |  |  |  | 335d | finish no earlier than 2005-12-16 | C6 | 1600h |  | APIJAVA | Sebastian Hans, Sun Microsystems Ltd. |  | Rel-7 | Gaby | 31.103, TS 102 241 |  |
| 191 | 58 | (Small) Technical Enhancements and Improvements for Rel-7 |  | 400d? | 2005-06-06 | 2006-12-15 |  |  |  |  |  | 75d | finish no earlier than 2006-12-15 | All | 3200h |  | TEI7 |  |  | Rel-7 |  |  |  |

Notes:
- 167: Started at GERAN#24
- 168: Started at GERAN#24
- 169: Not started
- 170: FS started
- 171: Conditionally, in the event Phase 2 is needed, end is Dec.06
- 176: WID approved SA#28
- 179: Created by MCC to group all VoIMS related items, after consultation of chairs
- 180: WID approved SA#28
- 182: Started
- 186: Placeholder created to Hold SA2 and CT1 BBs
- 187: Approved at SP#29
- 188: Approved at CP#29
- 189: Approved at SP#29

| ID | WBS | Task | Type | Duration | Start | Finish | Complete | Remaining | Baseline start | Baseline finish | Baseline duration | Total slack | Constraint | Resources | Work | Actual work | Text1 | Text6 | Text3 | Text4 | Text5 | Text8 | Text7 |
| --- | --- | --- | --- | --- | --- | --- | --- | --- | --- | --- | --- | --- | --- | --- | --- | --- | --- | --- | --- | --- | --- | --- | --- |
| 192 | 59 | **Rel7 Security enhancements** |  | 1d? | 2005-09-12 | 2005-09-12 |  |  |  |  |  | 404d |  | S3 | 40h |  | SEC7 | Rel-7 |  |  |  |  |  |
| 193 | 59.1 | HTTPS connection between a UICC and a NAF |  | 1d? | 2005-09-12 | 2005-09-12 |  |  |  |  |  | 404d | start no earlier than 2005-09-12 | S3 | 8h |  | HSUN | Rel-7 |  |  |  |  |  |
| 194 | 59.2 | 2G GBA: 2G SIM usage in 3GPP GAA framework |  | 1d? | 2005-09-12 | 2005-09-12 |  |  |  |  |  | 404d | start no earlier than 2005-09-12 | S3 | 8h |  | GBA2 | Rel-7 |  |  |  |  |  |
| 195 | 59.3 | Generic Authentication Architecture usage extensions and optimisations |  | 1d? | 2005-09-12 | 2005-09-12 |  |  |  |  |  | 404d | start no earlier than 2005-09-12 | S3 | 8h |  | GAA2 | Rel-7 |  |  |  |  |  |
| 196 | 59.4 | Network Domain Security; SS7 security Gateway (NDS/TCAPsec) |  | 1d? | 2005-09-12 | 2005-09-12 |  |  |  |  |  | 404d | start no earlier than 2005-09-12 | S3 | 8h |  | NDS-TCAPsec | Rel-7 |  |  |  |  |  |
| 197 | 60 | Rel-7 Feasibility Studies listed below |  | 1d? | 2000-01-03 | 2000-01-03 |  |  | 2000-01-03 | 2000-01-03 | 1d? | 1889d |  |  |  |  |  | Rel-7 |  |  |  |  |  |
| 198 | 61 | Study Item on IMS enhancements and optimisations for real time communication. | milestone | 0d? | 2005-10-10 A | 2006-10-20 |  | 0d? | 2005-10-10 | 2006-10-20 | 0d? | 115d | finish no earlier than 2006-09-22 | S2 |  |  | IMS-RT | Rel-7 | 23.8yz | Stephen Terrill (Ericsson) | stephen.terrill@ericsson.com | Maurice |  |
| 199 | 62 | Behaviour of Multi system UEs |  | 188d? | 2004-06-28 A | 2005-03-16 | 75% | 47d? | 2004-06-28 | 2005-03-16 | 188d? | 532d | start no earlier than 2004-06-28 | S1 | 1504h | 1128h | BMSU | Rel-7 | 22.936 | D Williams (QUALCOMM) | dwilliams@qualcomm.com | Michael | TSG |
| 200 | 63 | **FS on IMS with real time services deployment** |  | 384d? | 2004-06-28 A | 2005-12-15 | 78% | 82.57d? | 2004-06-28 | 2005-12-15 | 384d? | 336d |  | S1 | 10680h | 6676.24h | IRTSD | Rel-7 |  |  |  | Maurice | TSG |
| 201 | 63.1 | Feasibility Study on Combining CS calls and IMS sessions |  | 384d? | 2004-06-28 A | 2005-12-15 A | 100% |  | 2004-06-28 | 2005-12-15 | 384d? |  | start no earlier than 2004-06-28 | S1 | 3072h | 3072h | IRTSD-CS_IMS | Rel-7 | 22.979, 23.899 |  |  | Michael | TSG |
| 202 | 63.2 | TR on Stage 2 (IMS services using CS bearers) |  | 316d? | 2004-06-28 A | 2005-09-12 | 75% | 79d? | 2004-06-28 | 2005-09-12 | 316d? | 404d | finish no earlier than 2005-09-12 | S2 | 2528h | 1896h | IRTSD-IMSCS | Rel-7 | 23.899 | Mark Watson (Nortel Networks) |  | Maurice | TSG |
| 203 | 63.3 | Deleted - TS on Stage 2 (IMS services using CS bearers) |  | 251d? | 2004-06-28 A | 2005-06-13 | 50% | 125.5d? | 2004-06-28 | 2005-06-13 | 251d? | 469d | finish no earlier than 2005-06-13 | S2 | 2008h | 1004h | IRTSD-IMSCS | Rel-7 |  | Mark Watson (Nortel Networks) |  | Maurice | TSG |
| 204 | 64 | **3GPP System Architecture Evolution** |  | 401d? | 2004-12-03 A | 2006-06-16 | 8% | 367.12d? | 2004-12-03 | 2006-06-16 | 401d? | 205d |  | S2 | 8104h | 684.6h | SAE | Rel-7 |  |  |  |  | TSG |
| 205 | 64.1 | Stage 2 description of Interim conclusion |  | 211d? | 2004-12-03 A | 2005-09-23 | 15% | 179.35d? | 2004-12-03 | 2005-09-23 | 211d? | 395d | finish no earlier than 2005-09-23 | S2 | 1688h | 253.2h | SAE | Rel-7 | 23.8xx |  |  |  |  |
| 206 | 64.2 | Stage 2 Feasibility study on 3GPP architectural development |  | 401d? | 2004-12-03 A | 2006-06-16 | 5% | 380.95d? | 2004-12-03 | 2006-06-16 | 401d? | 205d | finish no earlier than 2006-06-16 | S2 | 3208h | 160.4h | SAE | Rel-7 | 23.8xx |  |  |  |  |
| 207 | 65 | FS on Performance Evaluation of the UE behaviour in high speed trains with speeds up to 350 kmph |  | 261d? | 2005-03-15 A | 2006-03-15 | 10% | 234.9d? | 2005-03-15 | 2006-03-15 | 261d? | 273d | finish no earlier than 2006-03-15 | R4 | 2088h | 208.8h | RANFS-HSTrains | Rel-7 |  | Mike Vogel | Mike.vogel@vodafone.com | MCC_RAN | TSG |
| 208 | 66 | FS of enhanced support of Video Telephony |  | 316d? | 2004-08-27 A | 2005-11-11 | 35% | 205.4d? | 2004-08-27 | 2005-11-11 | 316d? | 360d | finish no earlier than 2005-11-11 | GP | 2528h | 884.8h | VIDGER | Rel-7 |  | Stefan Eriksson, Ericsson | stefan.g.eriksson@ericsson.com | Paolo | TSG |
| 209 | 67 | FS on Evolved UTRA and UTRAN |  | 130d? | 2004-12-15 A | 2005-06-15 | 30% | 91d? | 2004-12-15 | 2005-06-15 | 130d? | 468d | finish no earlier than 2005-06-15 | RP | 1040h | 312h | RANFS-Evo | Rel-7 |  | Takehiro Nakamura (NTT DoCoMo) | nakamurata@NTTDOCOMO.CO.JP | MCC_RAN | TSG |
| 210 | 68 | **Study on Videotelephony teleservice** |  | 452d? | 2005-03-15 A | 2006-12-06 | 75% | 113d? | 2005-03-15 | 2006-12-06 | 452d? | 82d |  | S1 | 7232h | 5424h | VidTel | Rel-7 |  | Kurt Bischinger (T-Mobile) | kurt.bischinger@t-mobile.at | Michael | TSG |
| 211 | 68.1 | Study on Videotelephony service requirements |  | 452d? | 2005-03-15 A | 2006-12-06 | 75% | 113d? | 2005-03-15 | 2006-12-06 | 452d? | 82d | finish no earlier than 2006-12-06 | S1 | 3616h | 2712h | VidTel | Rel-7 | 22.903 | Kurt Bischinger (T-Mobile) | kurt.bischinger@t-mobile.at | Michael | TSG |
| 212 | 69 | **Study of Network Selection Principles** |  | 193d? | 2005-03-15 A | 2005-12-08 | 75% | 48.25d? | 2005-03-15 | 2005-12-08 | 193d? | 341d |  | S1 | 3088h | 2272.02h | NetSel | Rel-7 |  | Chris Friel (O2) | chris.friel@o2.com | Michael | TSG |
| 213 | 69.1 | Review of Network Selection Principles |  | 193d? | 2005-03-15 A | 2005-12-08 | 75% | 48.25d? | 2005-03-15 | 2005-12-08 | 193d? | 341d | finish no earlier than 2005-12-08 | S1 | 1544h | 1158h | NetSel | Rel-7 | 22.811 | Chris Friel (O2) | chris.friel@o2.com | Michael | TSG |
| 214 | 70 | FS on Enhancements to support QoS provisioning over 3GPP/WLAN Interworking |  | 391d? | 2005-03-14 A | 2006-09-11 | 25% | 293.25d? | 2005-03-14 | 2006-09-11 | 391d? | 144d | finish no earlier than 2006-09-11 | S2 | 3128h | 782h | WLAN-SC | Rel-7 |  | Osok Song, Samsung | osok.song@samsung.com | Maurice |  |
| 215 | 71 | FS on Continuous connectivity for packet data users |  | 132d? | 2005-03-15 A | 2005-09-15 A | 100% |  | 2005-03-15 | 2005-09-15 | 132d? |  | finish no earlier than 2005-09-15 | R1 | 1056h | 1056h | RANFS-cont-packet | Rel-7 |  | Joerg Gustrau | joerg.gustrau@siemens.com | MCC_RAN | TSG |
| 216 | 72 | FS on UTRA Tower Mounted Amplifier (FDD) |  | 195d? | 2005-06-15 A | 2006-03-15 | 10% | 175.5d? | 2005-06-15 | 2006-03-15 | 195d? | 273d | finish no earlier than 2006-03-15 | R4 | 1560h | 156h | RANFS-TMA | Rel-7 |  | Klas Sjerling | Klas.Sjerling@ericsson.com | MCC_RAN | TSG |
| 217 | 73 | Multimedia Priority Service |  | 450d? | 2003-03-28 A | 2004-12-16 | 60% | 180d? | 2003-03-28 | 2004-12-16 | 450d? | 596d | finish no earlier than 2004-12-16 | S1 | 3600h | 2160h |  | Rel-6 | 22.953 |  |  | Michael |  |

Notes:
- 193: Awaiting MCC SA3 input
- 194: Awaiting MCC SA3 input
- 195: Awaiting MCC SA3 input
- 196: Awaiting MCC SA3 input
- 198: Approved at SP#29
- 199: This is a feature in its own right.
- 203: covered by 32084
- 208: FS started
- 214: Approved SA#27. BB Position in Work Plan to be confirmed
- 217: Moved from Rel6

| ID | WBS | Task | Type | Duration | Start | Finish | Complete | Remaining | Baseline start | Baseline finish | Baseline duration | Total slack | Constraint | Resources | Work | Actual work | Text1 | Text3 | Text4 | Text5 | Text6 | Text7 | Text8 |
| --- | --- | --- | --- | --- | --- | --- | --- | --- | --- | --- | --- | --- | --- | --- | --- | --- | --- | --- | --- | --- | --- | --- | --- |
| 218 | 74 | **Selective Disabling of UE Capabilities** |  | 489.36d? | 2005-01-24 A | 2006-12-08 | 45% | 271.46d? | 2005-01-24 | 2006-12-08 | 489.36d? | 80d |  | S1 | 8308.8h | 3699.74h | SDoUE | 22.xxx | Nigel Barnes (Motorola Ltd) | Nigel.Barnes@motorola.com | Rel-7 | TSG | Michael |
| 219 | 74.1 | Stage 1 |  | 393.6d? | 2005-01-24 A | 2006-12-08 | 22% | 307.01d? | 2005-01-24 | 2006-12-08 | 393.6d? | 80d | finish no earlier than 2006-12-08 | S1 | 3148.8h | 692.74h | SDoUE-CRs | 22.101 | Nigel Barnes (Motorola Ltd) | Nigel.Barnes@motorola.com | Rel-7 | TSG | Michael |
| 220 | 74.2 | TR on different possible architectures |  | 195d? | 2005-03-21 A | 2005-12-16 | 90% | 19.5d? | 2005-03-21 | 2005-12-16 | 195d? | 335d | finish no earlier than 2005-12-16 | S2 | 1560h | 1404h | SDoUE | 23.805 |  |  | Rel-7 |  | Maurice |
| 221 | 75 | Personal Network (PN) and Personal Area Network (PAN) |  | 101.2d? | 2005-07-11 A | 2005-12-08 | 10% | 91.08d? | 2005-07-11 | 2005-12-08 | 101.2d? | 341d | finish no earlier than 2005-12-08 | S1 | 809.6h | 80.97h | PNPAN |  | Armin Toepfer, Vodafone | armin.toepfer@vodafone.com | Rel-7 |  | Mike |
| 222 | 76 | Multimedia Telephony Capabilities for IMS |  | 101.2d? | 2005-07-11 A | 2005-12-08 | 25% | 75.9d? | 2005-07-11 | 2005-12-08 | 101.2d? | 341d | finish no earlier than 2005-12-08 | S1 | 809.6h | 202.4h | MITE |  | Peter Bleckert, Ericsson | peter.bleckert @ericsson.com | Rel-7 |  | Mike |
| 223 | 77 | Transferring of emergency Call data |  | 109d? | 2005-07-11 A | 2005-12-08 | 20% | 87.2d? | 2005-07-11 | 2005-12-08 | 109d? | 341d | finish no earlier than 2005-12-08 | S1 | 872h | 174.4h | eCALL |  | Steve Vardy, (Motorola S.A.S) | steven.vardy@motorola.com | Rel-7 |  | Mike |
| 224 | 78 | MBMS Enhancements |  | 109d? | 2005-07-11 A | 2005-12-08 | 25% | 81.75d? | 2005-07-11 | 2005-12-08 | 109d? | 341d | finish no earlier than 2005-12-08 | S1 | 872h | 218h | MBMSE |  | Liu Hong, China Mobile | liuhongyfw@chinamobile.com | Rel-7 |  | Mike |
| 225 | 79 | IMS security extensions |  | 118d? | 2005-06-28 A | 2005-12-08 | 20% | 94.4d? | 2005-06-28 | 2005-12-08 | 118d? | 341d | start no earlier than 2005-06-28 | S3 | 944h | 188.8h | IMS-SE |  | Bengt Sahlin, Ericsson | Bengt.Sahlin@ericsson.com | Rel-7 |  | Mike |
| 226 | 80 | Check - Voice call continuity between CS and IMS (incl. I-WLAN) |  | 140d? | 2005-03-17 A | 2005-09-28 | 60% | 56d? | 2005-03-17 | 2005-09-28 | 140d? | 392d | finish no earlier than 2005-09-28 | S1 | 1120h | 672h | VCC |  | Luisa Marchetto, Cingular Wireless LLC | luisa.marchetto@cingular.com | Rel-7 |  | Mike |
| 227 | 81 | Multimedia interworking between IMS and CS networks |  | 181d? | 2005-09-23 | 2006-06-02 |  |  | 2005-09-23 | 2006-06-02 | 181d? | 215d | finish no earlier than 2006-06-02 | C3 | 1448h |  | MIW-IMS | 29.163 | Nico Gabriele, Vodafone UK | nico.gabriele@vodafone.com | Rel-7 |  | Seung Don |
| 228 | 82 | Study of a SMS Centre for MT SMS |  | 116d? | 2005-10-07 A | 2006-03-17 | 20% | 92.8d? | 2005-10-07 | 2006-03-17 | 116d? | 270d | start no earlier than 2005-10-07 | C4 | 928h | 185.6h | SMS7 | 23.840 | Nick Russell, Vodafone UK | Nick.Russell@vodafone.com | Rel-7 |  | Kimmo |
| 229 | 83 | Study of Customised Alerting Tone (CAT) Requirements |  | 1d? | 2005-09-12 | 2005-09-12 |  |  |  |  |  | 404d | start no earlier than 2005-09-12 | S1 | 8h |  | CAT |  |  |  | Rel-7 |  |  |
| 230 | 84 | Facilitating Machine to Machine Communication in GSM and UMTS (M2M) |  | 161d? | 2005-11-04 | 2006-06-16 |  |  |  |  |  | 205d | finish no earlier than 2006-06-16 | S1 | 1288h |  | M2M | 22.8xy | Juergen Merkel, Siemens AG |  | Rel-7 |  | Michael |
| 231 | 85 | **Deleted: FS on applicability of GALILEO for LCS** |  | 484d? | 2003-08-25 A | 2005-06-30 |  | 484d? | 2003-08-25 | 2005-06-30 | 484d? | 456d |  | S2 | 3872h | 1000h | Galileo |  |  |  | Rel-7 |  |  |
| 232 | 85.1 | Deleted - TR on Stage 2 | milestone | 0d? | 2005-06-30 A | 2005-06-30 A | 100% |  | 2005-06-30 | 2005-06-30 | 0d? |  | finish no earlier than 2005-06-30 | S2 |  |  | Galileo |  |  |  | Rel-7 |  |  |
| 233 | 85.2 | deleted - GERAN review of the TR | milestone | 0d? | 2003-08-25 | 2003-08-25 |  |  | 2003-08-25 | 2003-08-25 | 0d? | 940d | finish no earlier than 2003-08-25 | GP |  |  | Galileo |  |  |  | Rel-7 |  |  |
| 234 | 16.7 | **Deleted - IMS Local services** |  | 1158d? | 2001-01-01 A | 2005-06-08 | 68% | 367.35d? | 2001-01-01 | 2005-06-08 | 1158d? | 472d |  | S2 | 13072h | 5192.02h | IMSLocal | 23.228 |  |  | Rel-7 |  |  |
| 235 | 16.7.1 | Deleted - Stage 2 |  | 325d | 2001-01-01 A | 2002-03-29 A | 100% |  | 2001-01-01 | 2002-03-29 | 325d |  | start no earlier than 2001-01-01 | S2 | 2600h | 2600h | IMSLocal |  |  |  | Rel-7 |  |  |
| 236 | 86.2 | Delete - Stage 3 for IMS Local services |  | 151d? | 2004-11-10 | 2005-06-08 |  |  | 2004-11-10 | 2005-06-08 | 151d? | 472d | finish no earlier than 2005-06-08 | C1 | 1208h |  | IMSLocal |  | Keith Drage, Lucent | drage@lucent.com | Rel-7 |  |  |
| 237 | 87 | Deleted - IMS Phase 3 | milestone | 0d? | 2005-06-08 A | 2005-06-08 A | 100% |  | 2005-06-08 | 2005-06-08 | 0d? |  | finish no earlier than 2005-06-08 | S2 |  |  |  |  |  |  | Rel-7 |  |  |
| 238 | 88 | Deleted - Improvements of Radio Interface | milestone | 0d? | 2004-09-15 A | 2004-09-15 A | 100% |  | 2004-09-15 | 2004-09-15 | 0d? |  | start no earlier than 2004-09-15 | RP |  |  | RInImp |  |  | Rel-7 | Rel-7 | TSG | Cesar |
| 239 | 89 | **Deleted: Generic User Profile Phase 2** |  | 234.4d | 2005-10-06 A | 2006-08-31 |  | 234.4d | 2005-10-06 | 2006-08-31 | 234.4d | 151.6d |  | C4 |  |  |  |  |  |  | Rel-7 |  | Gaby |
| 240 | 30.4 | Deleted - Stage 3 - Common objects | milestone | 0d | 2005-10-06 A | 2006-08-31 |  | 0d | 2005-10-06 | 2006-08-31 | 0d | 151.6d | finish no earlier than 2005-10-06 | C4 |  |  |  | 24.241 |  |  | Rel-7 | TSG | Gaby |

Notes:
- 228: Study WI
- 229: Awaiting MCC SA3 input
- 235: DAB - Not yet required in SA2 as it exists in previous releases
- 238: Stage 2 description of Interim conclusion
- 239: Created at TSG#27 by A. Sultan because of the move to Rel-7 of "Common Objects".
- 240: No progress in CN4#26. This have to be moved to Rel-7. It was deleted from WID
